# HABILITACIÓN DE ACCESOS Y PLATAFORMAS Y MOVIMIENTO DE TIERRAS II PARTE - CUENCA CAÑETE

Schedule from Primavera P6, 2023-02-01 to 2023-12-18, data date 2023-02-01.

## Calendars

- Calendario ARCC turno unico: Mon-Sun 07:00-17:00.

## Schedule

| ID | WBS | Activity | Type | Duration | Start | Finish | Predecessors | Total float | Free float |
| --- | --- | --- | --- | --- | --- | --- | --- | --- | --- |
| 331 |  | FIN | milestone | 0d | 2023-12-18 | 2023-12-18 | 9, 10, 13, 17, 5, 293, 295, 305, 315, 324, 328, 329, 297 | 0d |  |
|  | 1 | **HITOS DEL PROYECTO** |  |  | 2023-02-01 | 2023-12-17 |  |  |  |
| 2 |  | Hito 1: Inicio de obra - Acceso al Sitio | milestone | 0d | 2023-02-01 | 2023-02-01 |  | 0d |  |
| 3 |  | Hito 2: Inicio de Habilitación y Mejoramiento de accesos | milestone | 0d | 2023-02-16 | 2023-02-16 | 2 FS+15d | 0d |  |
| 4 |  | Hito 3: Inicio de Movimiento de Tierras - Dique Paquete 2 | milestone | 0d | 2023-03-03 | 2023-03-03 | 3 FS+15d | 52d | 0d |
| 6 |  | Hito 5: Inicio de Movimiento de Tierras - Dique Paquete 3 | milestone | 0d | 2023-03-18 | 2023-03-18 | 3 FS+30d | 0d |  |
| 5 |  | Hito 4: Culminación de Diques Paquete 2 | milestone | 0d | 2023-05-31 | 2023-05-31 | 4 FS+90d, 25, 26, 29, 30, 43, 44, 45, 46, 47, 48 | 200d |  |
| 7 |  | Hito 6: Culminación de Diques Paquete 3 | milestone | 0d | 2023-12-17 | 2023-12-17 | 6 FS+275d, 55, 56, 59, 60, 73, 74, 75, 76, 77, 78, 85, 86, 103, 104, 105, 106, 107, 108, 111, 114, 115, 117, 123, 124, 126, 133, 134, 137, 138, 151, 152, 153, 154, 155, 156, 163, 164, 168, 171, 181, 182, 183, 184, 185, 186, 193, 194, 197, 198, 211, 212, 213, 214, 215, 222, 223, 226, 227, 240, 241, 242, 243, 244, 245, 252, 253, 270, 271, 272, 273, 274, 275, 283, 284, 290, 291, 281, 125, 280 | 0d |  |
|  | 2 | **OBRAS PROVISIONALES** |  |  | 2023-02-01 | 2023-12-17 |  |  |  |
| 10 |  | Movilización y Desmovilización de maquinaria pesada | resource dependent | 320d | 2023-02-01 | 2023-12-17 | 2 | 0d |  |
| 9 |  | Campamento Provisional de Obra | resource dependent | 30d | 2023-02-01 | 2023-03-02 | 2 | 290d |  |
| 12 |  | Limpieza manual de material vegetal y de residuos | resource dependent | 10d | 2023-02-16 | 2023-02-25 | 3 | 0d |  |
| 11 |  | Mejoramiento y Habilitación de caminos de acceso | resource dependent | 30d | 2023-02-26 | 2023-03-27 | 12 | 0d |  |
| 14 |  | Tubería HDPE Corrugada Ø=630mm, para caminos de acceso (o similar) | resource dependent | 10d | 2023-03-28 | 2023-04-06 | 11 | 0d |  |
| 15 |  | Tubería HDPE Corrugada Ø=1000mm, para caminos de acceso (o similar) | resource dependent | 15d | 2023-04-07 | 2023-04-21 | 14 | 0d |  |
| 13 |  | Mantenimiento de caminos de acceso | resource dependent | 240d | 2023-04-22 | 2023-12-17 | 15 | 0d |  |
|  | 3 | **TOPOGRAFIA** |  |  | 2023-02-01 | 2023-12-17 |  |  |  |
| 17 |  | Trazo y replanteo durante la obra | resource dependent | 320d | 2023-02-01 | 2023-12-17 | 2 | 0d |  |
|  | 4 | **CONSTRUCCION DE DIQUES** |  |  | 2023-03-03 | 2023-12-17 |  |  |  |
|  | 1 | **DIQUE DE-PR-07-I** |  |  | 2023-03-03 | 2023-05-31 |  |  |  |
|  | 1 | **Excavaciones** |  |  | 2023-03-03 | 2023-04-14 |  |  |  |
| 21 |  | Desbroce | resource dependent | 4d | 2023-03-03 | 2023-03-06 | 4 | 52d | 0d |
| 26 |  | Conformación de material excedente en DMO | resource dependent | 6d | 2023-03-03 | 2023-03-08 | 39 FS-4d, 40 FS-4d | 284d | 84d |
| 22 |  | Excavación de cimentación | resource dependent | 38d | 2023-03-07 | 2023-04-13 | 21 | 52d | 0d |
| 24 |  | Excavación de uña | resource dependent | 38d | 2023-03-07 | 2023-04-13 | 21 | 52d | 0d |
| 25 |  | Conformación de material excedente en DME | resource dependent | 38d | 2023-03-07 | 2023-04-13 | 41 FS-38d, 42 FS-38d | 248d | 48d |
| 23 |  | Perfilado y conformación de Plataforma de fundación | resource dependent | 37d | 2023-03-09 | 2023-04-14 | 22 FS-36d, 24 FS-36d | 52d | 0d |

Notes:
- 331: Expenses: FIN - (cost) 0
- 2: Expenses: Hito 1: Inicio de obra - Acceso al Sitio - (cost) 0
- 3: Expenses: Hito 2: Inicio de Habilitación y Mejoramiento de accesos - (cost) 0
- 4: Expenses: Hito 3: Inicio de Movimiento de Tierras - Dique Paquete 2 - (cost) 0
- 6: Expenses: Hito 5: Inicio de Movimiento de Tierras - Dique Paquete 3 - (cost) 0
- 5: Expenses: Hito 4: Culminación de Diques Paquete 2 - (cost) 0
- 7: Expenses: Hito 6: Culminación de Diques Paquete 3 - (cost) 0

| ID | WBS | Activity | Type | Duration | Start | Finish | Predecessors | Total float | Free float |
| --- | --- | --- | --- | --- | --- | --- | --- | --- | --- |
|  | 2 | **Rellenos** |  |  | 2023-03-11 | 2023-05-31 |  |  |  |
| 28 |  | Relleno con material granular (incluye extracción de material, zarandeo y combinación de material | resource dependent | 51d | 2023-03-11 | 2023-04-30 | 23 FS-35d | 52d | 0d |
| 31 |  | Perfilado de Talud del dique | resource dependent | 51d | 2023-03-12 | 2023-05-01 | 28 FS-50d | 52d | 0d |
| 29 |  | Relleno sin compactar | resource dependent | 24d | 2023-05-08 | 2023-05-31 | 36 FS-20d, 37 FS-20d | 200d | 0d |
| 30 |  | Relleno afirmado | resource dependent | 7d | 2023-05-25 | 2023-05-31 | 36 FS-3d, 37 FS-3d | 200d | 0d |
|  | 3 | **Geotextil** |  |  | 2023-03-23 | 2023-05-25 |  |  |  |
| 34 |  | Zanja de anclaje | resource dependent | 63d | 2023-03-23 | 2023-05-24 | 31 FS-40d | 52d | 0d |
| 33 |  | Instalación de Geotextil 400 gr/m2 | resource dependent | 63d | 2023-03-24 | 2023-05-25 | 34 FS-62d | 52d | 0d |
|  | 4 | **Colocación de roca** |  |  | 2023-03-25 | 2023-05-27 |  |  |  |
| 36 |  | Colocación de roca en uña | resource dependent | 64d | 2023-03-25 | 2023-05-27 | 33 FS-62d | 52d | 0d |
| 37 |  | Colocación de roca en Talud | resource dependent | 64d | 2023-03-25 | 2023-05-27 | 33 FS-62d | 52d | 0d |
|  | 5 | **Transportes** |  |  | 2023-03-03 | 2023-05-31 |  |  |  |
| 39 |  | Transporte de material orgánico (a DMO) D<=1km | resource dependent | 4d | 2023-03-03 | 2023-03-06 | 21 SS | 284d | 0d |
| 40 |  | Transporte de material orgánico (a DMO) D>1km | resource dependent | 4d | 2023-03-03 | 2023-03-06 | 21 SS | 284d | 0d |
| 41 |  | Transporte de material excedente (dique provisional) D<=1km | resource dependent | 38d | 2023-03-07 | 2023-04-13 | 22 SS, 24 SS | 248d | 0d |
| 42 |  | Transporte de material excedente (dique provisional) D> 1km | resource dependent | 38d | 2023-03-07 | 2023-04-13 | 22 SS, 24 SS | 248d | 0d |
| 47 |  | Transporte de material de préstamo cantera de rio (cuerpo de terraplén) D<=1km | resource dependent | 51d | 2023-03-11 | 2023-04-30 | 28 SS | 231d | 31d |
| 48 |  | Transporte de material de préstamo cantera de rio (cuerpo de terraplén) D>1km | resource dependent | 51d | 2023-03-11 | 2023-04-30 | 28 SS | 231d | 31d |
| 45 |  | Transporte de roca D<=1km | resource dependent | 64d | 2023-03-25 | 2023-05-27 | 36 SS, 37 SS | 204d | 4d |
| 46 |  | Transporte de roca D>1km | resource dependent | 64d | 2023-03-25 | 2023-05-27 | 36 SS, 37 SS | 204d | 4d |
| 43 |  | Transporte de material de préstamo (afirmado) D<=1km | resource dependent | 7d | 2023-05-25 | 2023-05-31 | 30 SS | 200d | 0d |
| 44 |  | Transporte de material de préstamo (afirmado) D>1km | resource dependent | 7d | 2023-05-25 | 2023-05-31 | 30 SS | 200d | 0d |
|  | 2 | **DIQUE DI-PR-19BIS-D** |  |  | 2023-03-18 | 2023-12-17 |  |  |  |
|  | 1 | **Excavaciones** |  |  | 2023-03-18 | 2023-04-20 |  |  |  |
| 51 |  | Desbroce | resource dependent | 5d | 2023-03-18 | 2023-03-22 | 6 | 0d |  |
| 56 |  | Conformación de material excedente en DMO | resource dependent | 5d | 2023-03-18 | 2023-03-22 | 69 FS-5d, 70 FS-5d | 270d |  |
| 52 |  | Excavación de cimentación | resource dependent | 28d | 2023-03-23 | 2023-04-19 | 51 | 0d |  |
| 54 |  | Excavación de uña | resource dependent | 28d | 2023-03-23 | 2023-04-19 | 51 | 0d |  |
| 55 |  | Conformación de material excedente en DME | resource dependent | 28d | 2023-03-23 | 2023-04-19 | 71 FS-28d, 72 FS-28d | 242d |  |
| 53 |  | Perfilado y conformación de Plataforma de fundación | resource dependent | 27d | 2023-03-25 | 2023-04-20 | 52 FS-26d, 54 FS-26d | 0d |  |

| ID | WBS | Activity | Type | Duration | Start | Finish | Predecessors | Total float | Free float |
| --- | --- | --- | --- | --- | --- | --- | --- | --- | --- |
|  | 2 | **Rellenos** |  |  | 2023-04-01 | 2023-12-17 |  |  |  |
| 58 |  | Relleno con material granular (incluye extracción de material, zarandeo y combinac | resource dependent | 105d | 2023-04-01 | 2023-07-14 | 53 FS-20d | 0d |  |
| 61 |  | Perfilado de Talud del dique | resource dependent | 105d | 2023-04-02 | 2023-07-15 | 58 FS-104d | 0d |  |
| 59 |  | Relleno sin compactar | resource dependent | 28d | 2023-11-20 | 2023-12-17 | 66 FS-20d, 67 FS-20d, 256 | 0d |  |
| 60 |  | Relleno afirmado | resource dependent | 24d | 2023-11-24 | 2023-12-17 | 66 FS-16d, 67 FS-16d, 257 | 0d |  |
|  | 3 | **Geotextil** |  |  | 2023-04-09 | 2023-12-08 |  |  |  |
| 64 |  | Zanja de anclaje | resource dependent | 243d | 2023-04-09 | 2023-12-07 | 61 FS-98d | 0d |  |
| 63 |  | Instalación de Geotextil 400 gr/m2 | resource dependent | 243d | 2023-04-10 | 2023-12-08 | 64 FS-242d | 0d |  |
|  | 4 | **Colocación de roca** |  |  | 2023-04-11 | 2023-12-09 |  |  |  |
| 66 |  | Colocación de roca en uña | resource dependent | 243d | 2023-04-11 | 2023-12-09 | 63 FS-242d | 0d |  |
| 67 |  | Colocación de roca en Talud | resource dependent | 243d | 2023-04-11 | 2023-12-09 | 63 FS-242d | 0d |  |
|  | 5 | **Transportes** |  |  | 2023-03-18 | 2023-12-17 |  |  |  |
| 69 |  | Transporte de material orgánico (a DMO) D<=1km | resource dependent | 5d | 2023-03-18 | 2023-03-22 | 51 SS | 270d | 0d |
| 70 |  | Transporte de material orgánico (a DMO) D>1km | resource dependent | 5d | 2023-03-18 | 2023-03-22 | 51 SS | 270d | 0d |
| 71 |  | Transporte de material excedente (dique provisional) D<=1km | resource dependent | 28d | 2023-03-23 | 2023-04-19 | 52 SS, 54 SS | 242d | 0d |
| 72 |  | Transporte de material excedente (dique provisional) D> 1km | resource dependent | 28d | 2023-03-23 | 2023-04-19 | 52 SS, 54 SS | 242d | 0d |
| 77 |  | Transporte de material de préstamo cantera de rio (cuerpo de terraplén) D<=1km | resource dependent | 105d | 2023-04-01 | 2023-07-14 | 58 SS | 156d |  |
| 78 |  | Transporte de material de préstamo cantera de rio (cuerpo de terraplén) D>1km | resource dependent | 105d | 2023-04-01 | 2023-07-14 | 58 SS | 156d |  |
| 75 |  | Transporte de roca D<=1km | resource dependent | 243d | 2023-04-11 | 2023-12-09 | 66 SS, 67 SS | 8d |  |
| 76 |  | Transporte de roca D>1km | resource dependent | 243d | 2023-04-11 | 2023-12-09 | 66 SS, 67 SS | 8d |  |
| 73 |  | Transporte de material de préstamo (afirmado) D<=1km | resource dependent | 24d | 2023-11-24 | 2023-12-17 | 60 SS | 0d |  |
| 74 |  | Transporte de material de préstamo (afirmado) D>1km | resource dependent | 24d | 2023-11-24 | 2023-12-17 | 60 SS | 0d |  |
|  | 3 | **DIQUE DE-PR-45-D** |  |  | 2023-03-18 | 2023-05-10 |  |  |  |
|  | 1 | **Excavaciones** |  |  | 2023-03-18 | 2023-03-26 |  |  |  |
| 81 |  | Desbroce | resource dependent | 3d | 2023-03-18 | 2023-03-20 | 6 | 114d | 0d |
| 85 |  | Conformación de material excedente en DME | resource dependent | 3d | 2023-03-19 | 2023-03-21 | 099 FS-2d, 100 FS-2d | 271d |  |
| 82 |  | Excavación de cimentación | resource dependent | 5d | 2023-03-21 | 2023-03-25 | 81 | 114d | 0d |
| 84 |  | Excavación de uña | resource dependent | 5d | 2023-03-21 | 2023-03-25 | 81 | 114d | 0d |
| 86 |  | Conformación de material excedente en DMO | resource dependent | 5d | 2023-03-21 | 2023-03-25 | 101 FS-5d, 102 FS-5d | 267d |  |
| 83 |  | Perfilado y conformación de Plataforma de fundación | resource dependent | 4d | 2023-03-23 | 2023-03-26 | 82 FS-3d, 84 FS-3d | 114d | 0d |

| ID | WBS | Activity | Type | Duration | Start | Finish | Predecessors | Total float | Free float |
| --- | --- | --- | --- | --- | --- | --- | --- | --- | --- |
|  | 2 | **Rellenos** |  |  | 2023-03-26 | 2023-05-10 |  |  |  |
| 88 |  | Relleno con material granular (incluye extracción de material, zarandeo y combinac | resource dependent | 12d | 2023-03-26 | 2023-04-06 | 83 FS-1d | 114d | 0d |
| 91 |  | Perfilado de Talud del dique | resource dependent | 12d | 2023-03-27 | 2023-04-07 | 88 FS-11d | 116d | 0d |
| 89 |  | Relleno sin compactar | resource dependent | 15d | 2023-04-26 | 2023-05-10 | 96 FS-3d, 97 FS-3d | 206d | 2d |
| 90 |  | Relleno afirmado | resource dependent | 15d | 2023-04-26 | 2023-05-10 | 96 FS-3d, 97 FS-3d | 206d | 0d |
|  | 3 | **Geotextil** |  |  | 2023-03-28 | 2023-04-27 |  |  |  |
| 94 |  | Zanja de anclaje | resource dependent | 30d | 2023-03-28 | 2023-04-26 | 91 FS-11d | 116d | 0d |
| 93 |  | Instalación de Geotextil 400 gr/m2 | resource dependent | 30d | 2023-03-29 | 2023-04-27 | 94 FS-29d | 116d | 0d |
|  | 4 | **Colocación de roca** |  |  | 2023-03-30 | 2023-04-28 |  |  |  |
| 96 |  | Colocación de roca en uña | resource dependent | 30d | 2023-03-30 | 2023-04-28 | 93 FS-29d | 116d | 0d |
| 97 |  | Colocación de roca en Talud | resource dependent | 30d | 2023-03-30 | 2023-04-28 | 93 FS-29d | 206d | 0d |
|  | 5 | **Transportes** |  |  | 2023-03-18 | 2023-05-10 |  |  |  |
| 099 |  | Transporte de material orgánico (a DMO) D<=1km | resource dependent | 3d | 2023-03-18 | 2023-03-20 | 81 SS | 271d | 0d |
| 100 |  | Transporte de material orgánico (a DMO) D>1km | resource dependent | 3d | 2023-03-18 | 2023-03-20 | 81 SS | 271d | 0d |
| 101 |  | Transporte de material excedente (dique provisional) D<=1km | resource dependent | 5d | 2023-03-21 | 2023-03-25 | 82 SS, 84 SS | 267d | 0d |
| 102 |  | Transporte de material excedente (dique provisional) D> 1km | resource dependent | 5d | 2023-03-21 | 2023-03-25 | 82 SS, 84 SS | 267d | 0d |
| 107 |  | Transporte de material de préstamo cantera de rio (cuerpo de terraplén) D<=1km | resource dependent | 12d | 2023-03-26 | 2023-04-06 | 88 SS | 255d |  |
| 108 |  | Transporte de material de préstamo cantera de rio (cuerpo de terraplén) D>1km | resource dependent | 12d | 2023-03-26 | 2023-04-06 | 88 SS | 255d |  |
| 105 |  | Transporte de roca D<=1km | resource dependent | 30d | 2023-03-30 | 2023-04-28 | 96 SS, 97 SS | 233d |  |
| 106 |  | Transporte de roca D>1km | resource dependent | 30d | 2023-03-30 | 2023-04-28 | 96 SS, 97 SS | 233d |  |
| 103 |  | Transporte de material de préstamo (afirmado) D<=1km | resource dependent | 15d | 2023-04-26 | 2023-05-10 | 90 SS | 221d |  |
| 104 |  | Transporte de material de préstamo (afirmado) D>1km | resource dependent | 15d | 2023-04-26 | 2023-05-10 | 90 SS | 221d |  |
|  | 4 | **DIQUE DI-PR-41A-D** |  |  | 2023-04-02 | 2023-04-27 |  |  |  |
|  | 1 | **Excavaciones** |  |  | 2023-04-02 | 2023-04-20 |  |  |  |
| 111 |  | Desbroce | resource dependent | 5d | 2023-04-02 | 2023-04-06 | 189 | 255d | 0d |
| 115 |  | Conformación de material excedente en DMO | resource dependent | 5d | 2023-04-02 | 2023-04-06 | 119 FS-5d, 120 FS-5d | 255d |  |
| 112 |  | Excavación de cimentación | resource dependent | 5d | 2023-04-14 | 2023-04-18 | 190 | 234d | 0d |
| 114 |  | Conformación de material excedente en DME | resource dependent | 5d | 2023-04-14 | 2023-04-18 | 121 FS-5d, 122 FS-5d | 243d |  |
| 113 |  | Perfilado y conformación de Plataforma de fundación | resource dependent | 5d | 2023-04-16 | 2023-04-20 | 191, 112 FS-3d | 234d | 0d |

| ID | WBS | Activity | Type | Duration | Start | Finish | Predecessors | Total float | Free float |
| --- | --- | --- | --- | --- | --- | --- | --- | --- | --- |
|  | 2 | **Rellenos** |  |  | 2023-04-21 | 2023-04-27 |  |  |  |
| 117 |  | Relleno con material granular (incluye extracción de material, zarandeo y combinac | resource dependent | 7d | 2023-04-21 | 2023-04-27 | 113 | 234d | 0d |
|  | 3 | **Transportes** |  |  | 2023-04-02 | 2023-04-27 |  |  |  |
| 119 |  | Transporte de material orgánico (a DMO) D<=1km | resource dependent | 5d | 2023-04-02 | 2023-04-06 | 111 SS | 255d | 0d |
| 120 |  | Transporte de material orgánico (a DMO) D>1km | resource dependent | 5d | 2023-04-02 | 2023-04-06 | 111 SS | 255d | 0d |
| 121 |  | Transporte de material excedente (dique provisional) D<=1km | resource dependent | 5d | 2023-04-14 | 2023-04-18 | 112 SS | 243d | 0d |
| 122 |  | Transporte de material excedente (dique provisional) D> 1km | resource dependent | 5d | 2023-04-14 | 2023-04-18 | 112 SS | 243d | 0d |
| 123 |  | Transporte de material de préstamo (afirmado) D<=1km | resource dependent | 7d | 2023-04-21 | 2023-04-27 | 117 SS | 234d |  |
| 124 |  | Transporte de material de préstamo (afirmado) D>1km | resource dependent | 7d | 2023-04-21 | 2023-04-27 | 117 SS | 234d |  |
| 125 |  | Transporte de material de préstamo cantera de rio (cuerpo de terraplén) D<=1km | resource dependent | 7d | 2023-04-21 | 2023-04-27 | 117 SS | 234d |  |
| 126 |  | Transporte de material de préstamo cantera de rio (cuerpo de terraplén) D>1km | resource dependent | 7d | 2023-04-21 | 2023-04-27 | 117 SS | 234d |  |
|  | 5 | **DIQUE DI-PR-41-D** |  |  | 2023-03-21 | 2023-05-27 |  |  |  |
|  | 1 | **Excavaciones** |  |  | 2023-03-21 | 2023-04-02 |  |  |  |
| 129 |  | Desbroce | resource dependent | 5d | 2023-03-21 | 2023-03-25 | 81 | 121d | 0d |
| 134 |  | Conformación de material excedente en DMO | resource dependent | 5d | 2023-03-21 | 2023-03-25 | 147 FS-5d, 148 FS-5d | 267d |  |
| 130 |  | Excavación de cimentación | resource dependent | 7d | 2023-03-26 | 2023-04-01 | 82, 129 | 121d | 0d |
| 132 |  | Excavación de uña | resource dependent | 7d | 2023-03-26 | 2023-04-01 | 84, 129 | 121d | 0d |
| 133 |  | Conformación de material excedente en DME | resource dependent | 7d | 2023-03-26 | 2023-04-01 | 149 FS-7d, 150 FS-7d | 260d |  |
| 131 |  | Perfilado y conformación de Plataforma de fundación | resource dependent | 6d | 2023-03-28 | 2023-04-02 | 83, 130 FS-5d, 132 FS-5d | 121d | 1d |
|  | 2 | **Rellenos** |  |  | 2023-04-07 | 2023-05-27 |  |  |  |
| 136 |  | Relleno con material granular (incluye extracción de material, zarandeo y combinac | resource dependent | 19d | 2023-04-07 | 2023-04-25 | 88, 131 FS-3d | 114d | 0d |
| 139 |  | Perfilado de Talud del dique | resource dependent | 19d | 2023-04-10 | 2023-04-28 | 91, 136 FS-16d | 114d | 0d |
| 137 |  | Relleno sin compactar | resource dependent | 15d | 2023-05-13 | 2023-05-27 | 89, 144 FS-13d, 145 FS-13d | 204d |  |
| 138 |  | Relleno afirmado | resource dependent | 15d | 2023-05-13 | 2023-05-27 | 90, 144 FS-13d, 145 FS-13d | 204d | 0d |

| ID | WBS | Activity | Type | Duration | Start | Finish | Predecessors | Total float | Free float |
| --- | --- | --- | --- | --- | --- | --- | --- | --- | --- |
|  | 3 | **Geotextil** |  |  | 2023-04-29 | 2023-05-24 |  |  |  |
| 142 |  | Zanja de anclaje | resource dependent | 25d | 2023-04-29 | 2023-05-23 | 94, 139 | 114d | 0d |
| 141 |  | Instalación de Geotextil 400 gr/m2 | resource dependent | 25d | 2023-04-30 | 2023-05-24 | 93, 142 FS-24d | 114d | 0d |
|  | 4 | **Colocación de roca** |  |  | 2023-05-01 | 2023-05-25 |  |  |  |
| 144 |  | Colocación de roca en uña | resource dependent | 25d | 2023-05-01 | 2023-05-25 | 96, 141 FS-24d | 114d | 0d |
| 145 |  | Colocación de roca en Talud | resource dependent | 25d | 2023-05-01 | 2023-05-25 | 97, 141 FS-24d | 204d | 0d |
|  | 5 | **Transportes** |  |  | 2023-03-21 | 2023-05-27 |  |  |  |
| 147 |  | Transporte de material orgánico (a DMO) D<=1km | resource dependent | 5d | 2023-03-21 | 2023-03-25 | 129 SS | 267d | 0d |
| 148 |  | Transporte de material orgánico (a DMO) D>1km | resource dependent | 5d | 2023-03-21 | 2023-03-25 | 129 SS | 267d | 0d |
| 149 |  | Transporte de material excedente (dique provisional) D<=1km | resource dependent | 7d | 2023-03-26 | 2023-04-01 | 130 SS, 132 SS | 260d | 0d |
| 150 |  | Transporte de material excedente (dique provisional) D> 1km | resource dependent | 7d | 2023-03-26 | 2023-04-01 | 130 SS, 132 SS | 260d | 0d |
| 155 |  | Transporte de material de préstamo cantera de rio (cuerpo de terraplén) D<=1km | resource dependent | 19d | 2023-04-07 | 2023-04-25 | 136 SS | 236d |  |
| 156 |  | Transporte de material de préstamo cantera de rio (cuerpo de terraplén) D>1km | resource dependent | 19d | 2023-04-07 | 2023-04-25 | 136 SS | 236d |  |
| 153 |  | Transporte de roca D<=1km | resource dependent | 25d | 2023-05-01 | 2023-05-25 | 144 SS, 145 SS | 206d |  |
| 154 |  | Transporte de roca D>1km | resource dependent | 25d | 2023-05-01 | 2023-05-25 | 144 SS, 145 SS | 206d |  |
| 151 |  | Transporte de material de préstamo (afirmado) D<=1km | resource dependent | 15d | 2023-05-13 | 2023-05-27 | 138 SS | 204d |  |
| 152 |  | Transporte de material de préstamo (afirmado) D>1km | resource dependent | 15d | 2023-05-13 | 2023-05-27 | 138 SS | 204d |  |
|  | 6 | **DIQUE DE-PR-19-D** |  |  | 2023-04-22 | 2023-10-26 |  |  |  |
|  | 1 | **Excavaciones** |  |  | 2023-04-22 | 2023-06-16 |  |  |  |
| 159 |  | Desbroce | resource dependent | 10d | 2023-04-22 | 2023-05-01 | 218 | 43d | 0d |
| 164 |  | Conformación de material excedente en DMO | resource dependent | 10d | 2023-04-22 | 2023-05-01 | 177 FS-10d, 178 FS-10d | 230d |  |
| 160 |  | Excavación de cimentación | resource dependent | 12d | 2023-05-04 | 2023-05-15 | 219, 159 | 54d | 0d |
| 163 |  | Conformación de material excedente en DME | resource dependent | 24d | 2023-05-04 | 2023-05-27 | 179 FS-24d, 180 FS-24d | 204d |  |
| 162 |  | Excavación de uña | resource dependent | 12d | 2023-05-16 | 2023-05-27 | 160 | 54d | 0d |
| 161 |  | Perfilado y conformación de Plataforma de fundación | resource dependent | 20d | 2023-05-28 | 2023-06-16 | 162 | 54d | 0d |

| ID | WBS | Activity | Type | Duration | Start | Finish | Predecessors | Total float | Free float |
| --- | --- | --- | --- | --- | --- | --- | --- | --- | --- |
|  | 2 | **Rellenos** |  |  | 2023-06-17 | 2023-10-26 |  |  |  |
| 166 |  | Relleno con material granular (incluye extracción de material, zarandeo y combinac | resource dependent | 45d | 2023-06-17 | 2023-07-31 | 225, 161 | 54d | 0d |
| 169 |  | Perfilado de Talud del dique | resource dependent | 46d | 2023-06-18 | 2023-08-02 | 228, 166 FS-44d | 54d | 0d |
| 167 |  | Relleno sin compactar | resource dependent | 12d | 2023-10-10 | 2023-10-21 | 174 FS-5d, 175 FS-5d | 52d | 0d |
| 168 |  | Relleno afirmado | resource dependent | 5d | 2023-10-22 | 2023-10-26 | 167 | 52d | 0d |
|  | 3 | **Geotextil** |  |  | 2023-08-03 | 2023-10-12 |  |  |  |
| 172 |  | Zanja de anclaje | resource dependent | 70d | 2023-08-03 | 2023-10-11 | 231, 169 | 54d | 0d |
| 171 |  | Instalación de Geotextil 400 gr/m2 | resource dependent | 70d | 2023-08-04 | 2023-10-12 | 230, 172 FS-69d | 66d |  |
|  | 4 | **Colocación de roca** |  |  | 2023-08-06 | 2023-10-14 |  |  |  |
| 174 |  | Colocación de roca en uña | resource dependent | 70d | 2023-08-06 | 2023-10-14 | 233, 172 FS-69d | 52d | 0d |
| 175 |  | Colocación de roca en Talud | resource dependent | 70d | 2023-08-06 | 2023-10-14 | 234, 172 FS-69d | 52d | 0d |
|  | 5 | **Transportes** |  |  | 2023-04-22 | 2023-10-26 |  |  |  |
| 177 |  | Transporte de material orgánico (a DMO) D<=1km | resource dependent | 10d | 2023-04-22 | 2023-05-01 | 159 SS | 230d | 0d |
| 178 |  | Transporte de material orgánico (a DMO) D>1km | resource dependent | 10d | 2023-04-22 | 2023-05-01 | 159 SS | 230d | 0d |
| 179 |  | Transporte de material excedente (dique provisional) D<=1km | resource dependent | 24d | 2023-05-04 | 2023-05-27 | 160 SS | 204d | 0d |
| 180 |  | Transporte de material excedente (dique provisional) D> 1km | resource dependent | 24d | 2023-05-04 | 2023-05-27 | 160 SS | 204d | 0d |
| 185 |  | Transporte de material de préstamo cantera de rio (cuerpo de terraplén) D<=1km | resource dependent | 45d | 2023-06-17 | 2023-07-31 | 166 SS | 139d |  |
| 186 |  | Transporte de material de préstamo cantera de rio (cuerpo de terraplén) D>1km | resource dependent | 45d | 2023-06-17 | 2023-07-31 | 166 SS | 139d |  |
| 183 |  | Transporte de roca D<=1km | resource dependent | 70d | 2023-08-06 | 2023-10-14 | 174 SS, 175 SS | 64d |  |
| 184 |  | Transporte de roca D>1km | resource dependent | 70d | 2023-08-06 | 2023-10-14 | 174 SS, 175 SS | 64d |  |
| 181 |  | Transporte de material de préstamo (afirmado) D<=1km | resource dependent | 5d | 2023-10-22 | 2023-10-26 | 168 SS | 52d |  |
| 182 |  | Transporte de material de préstamo (afirmado) D>1km | resource dependent | 5d | 2023-10-22 | 2023-10-26 | 168 SS | 52d |  |
|  | 7 | **DIQUE DI-PR-44-D** |  |  | 2023-03-26 | 2023-08-25 |  |  |  |
|  | 1 | **Excavaciones** |  |  | 2023-03-26 | 2023-04-14 |  |  |  |
| 189 |  | Desbroce | resource dependent | 7d | 2023-03-26 | 2023-04-01 | 129 | 127d | 0d |
| 194 |  | Conformación de material excedente en DMO | resource dependent | 7d | 2023-03-26 | 2023-04-01 | 207 FS-7d, 208 FS-7d | 260d |  |
| 190 |  | Excavación de cimentación | resource dependent | 12d | 2023-04-02 | 2023-04-13 | 130, 189 | 127d | 0d |
| 192 |  | Excavación de uña | resource dependent | 12d | 2023-04-02 | 2023-04-13 | 132, 189 | 127d | 0d |
| 193 |  | Conformación de material excedente en DME | resource dependent | 12d | 2023-04-02 | 2023-04-13 | 209 FS-12d, 210 FS-12d | 248d |  |
| 191 |  | Perfilado y conformación de Plataforma de fundación | resource dependent | 11d | 2023-04-04 | 2023-04-14 | 131, 190 FS-10d, 192 FS-10d | 127d | 1d |

| ID | WBS | Activity | Type | Duration | Start | Finish | Predecessors | Total float | Free float |
| --- | --- | --- | --- | --- | --- | --- | --- | --- | --- |
|  | 2 | **Rellenos** |  |  | 2023-04-26 | 2023-08-25 |  |  |  |
| 196 |  | Relleno con material granular (incluye extracción de material, zarandeo y combinac | resource dependent | 33d | 2023-04-26 | 2023-05-28 | 136, 191 | 116d | 0d |
| 199 |  | Perfilado de Talud del dique | resource dependent | 33d | 2023-04-29 | 2023-05-31 | 139, 196 FS-32d | 114d | 0d |
| 197 |  | Relleno sin compactar | resource dependent | 15d | 2023-08-11 | 2023-08-25 | 204 FS-11d, 205 FS-11d | 114d |  |
| 198 |  | Relleno afirmado | resource dependent | 7d | 2023-08-19 | 2023-08-25 | 204 FS-3d, 205 FS-3d | 114d | 0d |
|  | 3 | **Geotextil** |  |  | 2023-05-24 | 2023-08-20 |  |  |  |
| 202 |  | Zanja de anclaje | resource dependent | 88d | 2023-05-24 | 2023-08-19 | 199 FS-8d, 142 | 114d | 0d |
| 201 |  | Instalación de Geotextil 400 gr/m2 | resource dependent | 88d | 2023-05-25 | 2023-08-20 | 202 FS-87d, 141 | 114d | 0d |
|  | 4 | **Colocación de roca** |  |  | 2023-05-26 | 2023-08-21 |  |  |  |
| 204 |  | Colocación de roca en uña | resource dependent | 88d | 2023-05-26 | 2023-08-21 | 201 FS-87d | 114d | 0d |
| 205 |  | Colocación de roca en Talud | resource dependent | 88d | 2023-05-26 | 2023-08-21 | 201 FS-87d, 144 | 114d | 0d |
|  | 5 | **Transportes** |  |  | 2023-03-26 | 2023-08-25 |  |  |  |
| 207 |  | Transporte de material orgánico (a DMO) D<=1km | resource dependent | 7d | 2023-03-26 | 2023-04-01 | 189 SS | 260d | 0d |
| 208 |  | Transporte de material orgánico (a DMO) D>1km | resource dependent | 7d | 2023-03-26 | 2023-04-01 | 189 SS | 260d | 0d |
| 209 |  | Transporte de material excedente (dique provisional) D<=1km | resource dependent | 12d | 2023-04-02 | 2023-04-13 | 190 SS, 192 SS | 248d | 0d |
| 210 |  | Transporte de material excedente (dique provisional) D> 1km | resource dependent | 12d | 2023-04-02 | 2023-04-13 | 190 SS, 192 SS | 248d | 0d |
| 215 |  | Transporte de material de préstamo cantera de rio (cuerpo de terraplén) D<=1km | resource dependent | 33d | 2023-04-26 | 2023-05-28 | 196 SS | 203d |  |
| 213 |  | Transporte de roca D<=1km | resource dependent | 88d | 2023-05-26 | 2023-08-21 | 204 SS, 205 SS | 118d |  |
| 214 |  | Transporte de roca D>1km | resource dependent | 88d | 2023-05-26 | 2023-08-21 | 204 SS, 205 SS | 118d |  |
| 211 |  | Transporte de material de préstamo (afirmado) D<=1km | resource dependent | 7d | 2023-08-19 | 2023-08-25 | 198 SS | 114d |  |
| 212 |  | Transporte de material de préstamo (afirmado) D>1km | resource dependent | 7d | 2023-08-19 | 2023-08-25 | 198 SS | 114d |  |
|  | 8 | **DIQUE DI-PR-18-I** |  |  | 2023-04-17 | 2023-08-07 |  |  |  |
|  | 1 | **Excavaciones** |  |  | 2023-04-17 | 2023-05-04 |  |  |  |
| 218 |  | Desbroce | resource dependent | 5d | 2023-04-17 | 2023-04-21 | 6 FS+30d | 43d | 0d |
| 223 |  | Conformación de material excedente en DMO | resource dependent | 5d | 2023-04-17 | 2023-04-21 | 236 FS-5d, 237 FS-5d | 240d |  |
| 219 |  | Excavación de cimentación | resource dependent | 12d | 2023-04-22 | 2023-05-03 | 218 | 53d | 0d |
| 221 |  | Excavación de uña | resource dependent | 12d | 2023-04-22 | 2023-05-03 | 218 | 53d | 0d |
| 222 |  | Conformación de material excedente en DME | resource dependent | 12d | 2023-04-22 | 2023-05-03 | 238 FS-12d, 239 FS-12d | 228d |  |
| 220 |  | Perfilado y conformación de Plataforma de fundación | resource dependent | 11d | 2023-04-24 | 2023-05-04 | 219 FS-10d, 221 FS-10d | 53d | 0d |

| ID | WBS | Activity | Type | Duration | Start | Finish | Predecessors | Total float | Free float |
| --- | --- | --- | --- | --- | --- | --- | --- | --- | --- |
|  | 2 | **Rellenos** |  |  | 2023-05-01 | 2023-08-07 |  |  |  |
| 225 |  | Relleno con material granular (incluye extracción de material, zarandeo y combinac | resource dependent | 47d | 2023-05-01 | 2023-06-16 | 28, 220 FS-4d | 53d | 0d |
| 228 |  | Perfilado de Talud del dique | resource dependent | 47d | 2023-05-02 | 2023-06-17 | 225 FS-46d | 53d | 0d |
| 226 |  | Relleno sin compactar | resource dependent | 15d | 2023-07-24 | 2023-08-07 | 233 FS-13d, 234 FS-13d | 132d |  |
| 227 |  | Relleno afirmado | resource dependent | 15d | 2023-07-24 | 2023-08-07 | 233 FS-13d, 234 FS-13d | 132d | 0d |
|  | 3 | **Geotextil** |  |  | 2023-05-25 | 2023-08-03 |  |  |  |
| 231 |  | Zanja de anclaje | resource dependent | 70d | 2023-05-25 | 2023-08-02 | 34, 228 FS-24d | 53d | 0d |
| 230 |  | Instalación de Geotextil 400 gr/m2 | resource dependent | 70d | 2023-05-26 | 2023-08-03 | 33, 231 FS-69d | 53d | 0d |
|  | 4 | **Colocación de roca** |  |  | 2023-05-28 | 2023-08-05 |  |  |  |
| 233 |  | Colocación de roca en uña | resource dependent | 70d | 2023-05-28 | 2023-08-05 | 36, 230 FS-69d | 52d | 0d |
| 234 |  | Colocación de roca en Talud | resource dependent | 70d | 2023-05-28 | 2023-08-05 | 37, 230 FS-69d | 52d | 0d |
|  | 5 | **Transportes** |  |  | 2023-04-17 | 2023-08-07 |  |  |  |
| 236 |  | Transporte de material orgánico (a DMO) D<=1km | resource dependent | 5d | 2023-04-17 | 2023-04-21 | 218 SS | 240d | 0d |
| 237 |  | Transporte de material orgánico (a DMO) D>1km | resource dependent | 5d | 2023-04-17 | 2023-04-21 | 218 SS | 240d | 0d |
| 238 |  | Transporte de material excedente (dique provisional) D<=1km | resource dependent | 12d | 2023-04-22 | 2023-05-03 | 219 SS, 221 SS | 228d | 0d |
| 239 |  | Transporte de material excedente (dique provisional) D> 1km | resource dependent | 12d | 2023-04-22 | 2023-05-03 | 219 SS, 221 SS | 228d | 0d |
| 244 |  | Transporte de material de préstamo cantera de rio (cuerpo de terraplén) D<=1km | resource dependent | 47d | 2023-05-01 | 2023-06-16 | 225 SS | 184d |  |
| 245 |  | Transporte de material de préstamo cantera de rio (cuerpo de terraplén) D>1km | resource dependent | 47d | 2023-05-01 | 2023-06-16 | 225 SS | 184d |  |
| 242 |  | Transporte de roca D<=1km | resource dependent | 70d | 2023-05-28 | 2023-08-05 | 233 SS, 234 SS | 134d |  |
| 243 |  | Transporte de roca D>1km | resource dependent | 70d | 2023-05-28 | 2023-08-05 | 233 SS, 234 SS | 134d |  |
| 240 |  | Transporte de material de préstamo (afirmado) D<=1km | resource dependent | 15d | 2023-07-24 | 2023-08-07 | 227 SS | 132d |  |
| 241 |  | Transporte de material de préstamo (afirmado) D>1km | resource dependent | 15d | 2023-07-24 | 2023-08-07 | 227 SS | 132d |  |
|  | 9 | **DIQUE DI-PR-20-D** |  |  | 2023-03-18 | 2023-11-23 |  |  |  |
|  | 1 | **Excavaciones** |  |  | 2023-03-18 | 2023-04-19 |  |  |  |
| 248 |  | Desbroce | resource dependent | 5d | 2023-03-18 | 2023-03-22 | 6 | 0d |  |
| 253 |  | Conformación de material excedente en DMO | resource dependent | 9d | 2023-03-18 | 2023-03-26 | 266 FS-5d, 267 FS-5d | 266d |  |
| 249 |  | Excavación de cimentación | resource dependent | 27d | 2023-03-23 | 2023-04-18 | 248 | 0d |  |
| 251 |  | Excavación de uña | resource dependent | 27d | 2023-03-23 | 2023-04-18 | 248 | 0d |  |
| 252 |  | Conformación de material excedente en DME | resource dependent | 28d | 2023-03-23 | 2023-04-19 | 268 FS-27d, 269 FS-27d | 242d |  |
| 250 |  | Perfilado y conformación de Plataforma de fundación | resource dependent | 26d | 2023-03-25 | 2023-04-19 | 249 FS-25d, 251 FS-25d | 0d |  |

| ID | WBS | Activity | Type | Duration | Start | Finish | Predecessors | Total float | Free float |
| --- | --- | --- | --- | --- | --- | --- | --- | --- | --- |
|  | 2 | **Rellenos** |  |  | 2023-03-31 | 2023-11-23 |  |  |  |
| 255 |  | Relleno con material granular (incluye extracción de material, zarandeo y combinac | resource dependent | 105d | 2023-03-31 | 2023-07-13 | 250 FS-20d | 0d |  |
| 258 |  | Perfilado de Talud del dique | resource dependent | 105d | 2023-04-01 | 2023-07-14 | 255 FS-104d | 0d |  |
| 256 |  | Relleno sin compactar | resource dependent | 32d | 2023-10-19 | 2023-11-19 | 263 FS-15d, 264 FS-15d | 0d |  |
| 257 |  | Relleno afirmado | resource dependent | 21d | 2023-11-03 | 2023-11-23 | 263 | 0d |  |
|  | 3 | **Geotextil** |  |  | 2023-04-08 | 2023-11-01 |  |  |  |
| 261 |  | Zanja de anclaje | resource dependent | 207d | 2023-04-08 | 2023-10-31 | 258 FS-98d | 0d |  |
| 260 |  | Instalación de Geotextil 400 gr/m2 | resource dependent | 207d | 2023-04-09 | 2023-11-01 | 261 FS-206d | 0d |  |
|  | 4 | **Colocación de roca** |  |  | 2023-04-10 | 2023-11-02 |  |  |  |
| 263 |  | Colocación de roca en uña | resource dependent | 207d | 2023-04-10 | 2023-11-02 | 260 FS-206d | 0d |  |
| 264 |  | Colocación de roca en Talud | resource dependent | 207d | 2023-04-10 | 2023-11-02 | 260 FS-206d | 0d |  |
|  | 5 | **Transportes** |  |  | 2023-03-18 | 2023-11-23 |  |  |  |
| 266 |  | Transporte de material orgánico (a DMO) D<=1km | resource dependent | 5d | 2023-03-18 | 2023-03-22 | 248 SS | 266d | 0d |
| 267 |  | Transporte de material orgánico (a DMO) D>1km | resource dependent | 5d | 2023-03-18 | 2023-03-22 | 248 SS | 266d | 0d |
| 268 |  | Transporte de material excedente (dique provisional) D<=1km | resource dependent | 27d | 2023-03-23 | 2023-04-18 | 249 SS, 251 SS | 242d | 0d |
| 269 |  | Transporte de material excedente (dique provisional) D> 1km | resource dependent | 27d | 2023-03-23 | 2023-04-18 | 249 SS, 251 SS | 242d | 0d |
| 274 |  | Transporte de material de préstamo cantera de rio (cuerpo de terraplén) D<=1km | resource dependent | 105d | 2023-03-31 | 2023-07-13 | 255 SS | 157d |  |
| 275 |  | Transporte de material de préstamo cantera de rio (cuerpo de terraplén) D>1km | resource dependent | 105d | 2023-03-31 | 2023-07-13 | 255 SS | 157d |  |
| 272 |  | Transporte de roca D<=1km | resource dependent | 207d | 2023-04-10 | 2023-11-02 | 263 SS, 264 SS | 45d |  |
| 273 |  | Transporte de roca D>1km | resource dependent | 207d | 2023-04-10 | 2023-11-02 | 263 SS, 264 SS | 45d |  |
| 270 |  | Transporte de material de préstamo (afirmado) D<=1km | resource dependent | 21d | 2023-11-03 | 2023-11-23 | 257 SS | 24d |  |
| 271 |  | Transporte de material de préstamo (afirmado) D>1km | resource dependent | 21d | 2023-11-03 | 2023-11-23 | 257 SS | 24d |  |
|  | 10 | **DIQUE DI-PR-39-I** |  |  | 2023-05-02 | 2023-11-04 |  |  |  |
|  | 1 | **Excavaciones** |  |  | 2023-05-02 | 2023-06-15 |  |  |  |
| 278 |  | Desbroce | resource dependent | 5d | 2023-05-02 | 2023-05-06 | 159 | 43d | 0d |
| 281 |  | Conformación de material excedente en DMO | resource dependent | 5d | 2023-05-02 | 2023-05-06 | 286 FS-5d, 287 FS-5d | 225d |  |
| 279 |  | Excavación bajo nivel freático | resource dependent | 40d | 2023-05-07 | 2023-06-15 | 278 | 43d | 0d |
| 280 |  | Conformación de material excedente en DME | resource dependent | 40d | 2023-05-07 | 2023-06-15 | 288 FS-40d, 289 FS-40d | 185d |  |

| ID | WBS | Activity | Type | Duration | Start | Finish | Predecessors | Total float | Free float |
| --- | --- | --- | --- | --- | --- | --- | --- | --- | --- |
|  | 2 | **Colocación de roca** |  |  | 2023-06-16 | 2023-11-04 |  |  |  |
| 283 |  | Colocación de roca en uña | resource dependent | 142d | 2023-06-16 | 2023-11-04 | 279 | 43d | 0d |
| 284 |  | Colocación de roca en Talud | resource dependent | 142d | 2023-06-16 | 2023-11-04 | 279 | 43d | 0d |
|  | 3 | **Transportes** |  |  | 2023-05-02 | 2023-11-04 |  |  |  |
| 286 |  | Transporte de material orgánico (a DMO) D<=1km | resource dependent | 5d | 2023-05-02 | 2023-05-06 | 278 SS | 225d | 0d |
| 287 |  | Transporte de material orgánico (a DMO) D>1km | resource dependent | 5d | 2023-05-02 | 2023-05-06 | 278 SS | 225d | 0d |
| 288 |  | Transporte de material excedente (dique provisional) D<=1km | resource dependent | 40d | 2023-05-07 | 2023-06-15 | 279 SS | 185d | 0d |
| 289 |  | Transporte de material excedente (dique provisional) D> 1km | resource dependent | 40d | 2023-05-07 | 2023-06-15 | 279 SS | 185d | 0d |
| 290 |  | Transporte de roca D<=1km | resource dependent | 142d | 2023-06-16 | 2023-11-04 | 283 SS, 284 SS | 43d |  |
| 291 |  | Transporte de roca D>1km | resource dependent | 142d | 2023-06-16 | 2023-11-04 | 283 SS, 284 SS | 43d |  |
|  | 5 | **SEÑALIZACIÓN** |  |  | 2023-02-01 | 2023-12-17 |  |  |  |
| 293 |  | Señalización de obra | resource dependent | 320d | 2023-02-01 | 2023-12-17 | 2 | 0d |  |
|  | 6 | **CALIDAD** |  |  | 2023-02-01 | 2023-12-17 |  |  |  |
| 295 |  | Control de calidad | resource dependent | 320d | 2023-02-01 | 2023-12-17 | 2 | 0d |  |
|  | 7 | **OBRAS CIVILES** |  |  | 2023-02-01 | 2023-12-17 |  |  |  |
| 297 |  | Trazo y replanteo de interferencia | resource dependent | 320d | 2023-02-01 | 2023-12-17 | 2 | 0d |  |
| 300 |  | Limpieza de terreno manual | resource dependent | 12d | 2023-02-01 | 2023-02-12 | 2 | 0d |  |
| 298 |  | Desvío provisional con tubería | resource dependent | 28d | 2023-02-02 | 2023-03-01 | 300 FS-11d | 0d |  |
| 299 |  | Desvío provisional en tierras | resource dependent | 93d | 2023-03-02 | 2023-06-02 | 298 | 0d |  |
| 301 |  | Excavaciones no clasificada para estructuras | resource dependent | 7d | 2023-03-17 | 2023-03-23 | 299 FS-78d | 0d |  |
| 302 |  | Excavacion no clasificada de zanja | resource dependent | 137d | 2023-03-24 | 2023-08-07 | 301 | 0d |  |
| 303 |  | Relleno estructural | resource dependent | 44d | 2023-06-29 | 2023-08-11 | 302 FS-40d | 0d |  |
| 310 |  | Encofrado y Desencofrado Caravista | resource dependent | 45d | 2023-07-28 | 2023-09-10 | 303 FS-15d | 0d |  |
| 312 |  | Acero de refuerzo f'y=4200kg/cm2 | resource dependent | 115d | 2023-07-28 | 2023-11-19 | 303 FS-15d | 0d |  |
| 304 |  | Suministro de roca (Alcantarillas) | resource dependent | 19d | 2023-08-12 | 2023-08-30 | 303 | 104d | 0d |
| 306 |  | Concreto de Nivelacion (f'c=100 kg/cm2) | resource dependent | 5d | 2023-08-12 | 2023-08-16 | 303 | 0d |  |
| 307 |  | Concreto Clase F (f'c=140 kg/cm2) | resource dependent | 7d | 2023-08-17 | 2023-08-23 | 306, 310 FS-25d | 0d |  |
| 308 |  | Concreto Clase C (f'c=280 kg/cm2) Premezclado - Cimientos reforzados | resource dependent | 44d | 2023-08-24 | 2023-10-06 | 307 | 0d |  |
| 305 |  | Colocación de roca en uña (Alcantarillas) | resource dependent | 5d | 2023-08-31 | 2023-09-04 | 304 | 104d |  |
| 316 |  | Cama de arena e=0.20m | resource dependent | 10d | 2023-09-10 | 2023-09-19 | 303, 308 FS-27d | 0d |  |
| 311 |  | Encofrado y Desencofrado Cara Oculta | resource dependent | 70d | 2023-09-11 | 2023-11-19 | 310 | 0d |  |
| 317 |  | Tubería HDPE Corrugada Ø=900mm (Suministro e instalación) | resource dependent | 3d | 2023-09-20 | 2023-09-22 | 316 | 0d |  |
| 318 |  | Tubería HDPE Corrugada Ø=1200mm (Suministro e instalación) | resource dependent | 2d | 2023-09-23 | 2023-09-24 | 317 | 0d |  |
| 319 |  | Compuertas Charnela Ø900 (Suministro e instalacion) | resource dependent | 9d | 2023-09-25 | 2023-10-03 | 318 | 0d |  |
| 313 |  | Emboquillado de piedra e=0.20m | resource dependent | 55d | 2023-10-03 | 2023-11-26 | 309 FS-50d | 0d |  |
| 320 |  | Compuertas Charnela Ø1200 (Suministro e instalacion) | resource dependent | 3d | 2023-10-04 | 2023-10-06 | 319 | 0d |  |
| 309 |  | Concreto Clase C (f'c=280 kg/cm2) Premezclado - Muros de contencion | resource dependent | 46d | 2023-10-07 | 2023-11-21 | 308, 311 FS-44d, 312 FS-44d | 0d |  |
| 321 |  | Sello en juntas | resource dependent | 18d | 2023-10-07 | 2023-10-24 | 320 | 0d |  |
| 322 |  | Waterstop (anillos de estanqueidad) | resource dependent | 3d | 2023-10-25 | 2023-10-27 | 321 | 0d |  |
| 323 |  | Pintura bituminosa | resource dependent | 33d | 2023-10-28 | 2023-11-29 | 322 | 0d |  |
| 314 |  | Emboquillado de piedra e=0.30m | resource dependent | 10d | 2023-11-27 | 2023-12-06 | 313 | 0d |  |
| 324 |  | Relleno con material granular (incluye extracción de material, zarandeo y combinac | resource dependent | 18d | 2023-11-30 | 2023-12-17 | 323 | 0d |  |
| 315 |  | Emboquillado de piedra e=0.50m | resource dependent | 11d | 2023-12-07 | 2023-12-17 | 314 | 0d |  |

| ID | WBS | Activity | Type | Duration | Start | Finish | Predecessors | Total float |
| --- | --- | --- | --- | --- | --- | --- | --- | --- |
|  | 8 | **ACCESOS** |  |  | 2023-11-20 | 2023-12-17 |  |  |
|  | 1 | **Superficie de rodadura** |  |  | 2023-11-20 | 2023-12-17 |  |  |
| 328 |  | Encofrado y desencofrado pavimento rígido e=0.15m | resource dependent | 22d | 2023-11-20 | 2023-12-11 | 311 | 6d |
| 330 |  | Concreto Ciclopeo f'c=210 kg/cm2 + 30% PM | resource dependent | 8d | 2023-11-22 | 2023-11-29 | 309 | 0d |
| 327 |  | Concreto clase C (f'c=280 kg/cm2) en losa | resource dependent | 15d | 2023-11-30 | 2023-12-14 | 330 | 0d |
| 329 |  | Junta en Pavimentos con Pasadores | resource dependent | 3d | 2023-12-15 | 2023-12-17 | 327 | 0d |
