# HABILITACIÓN DE ACCESOS Y PLATAFORMAS, Y MOVIMIENTO DE TIERRAS II PARTE - CUENCA CAÑETE

Schedule from MS Project, 2023-02-01 to 2023-12-17, 10 hours a day.

## Calendars

- 2302: Mon-Sun 07:00-12:00, 13:00-18:00.

## Resources

| Resource |
| --- |
| 52 |
| 53 |
| 56 |
| 57 |
| 70 |
| 71 |
| 72 |
| 73 |
| 74 |
| 75 |
| 82 |
| 83 |
| 100 |
| 101 |
| 102 |
| 103 |
| 104 |
| 105 |
| 108 |
| 111 |
| 112 |
| 114 |
| 120 |
| 121 |
| 123 |
| 124 |
| 130 |
| 131 |
| 134 |
| 135 |
| 148 |
| 149 |
| 150 |
| 151 |
| 152 |
| 152153 |
| 153 |

## Schedule

| ID | WBS | Task | Type | Duration | Start | Finish | Predecessors | Total slack | Free slack |
| --- | --- | --- | --- | --- | --- | --- | --- | --- | --- |
| 1 | 1 | **HITOS DEL PROYECTO** |  | 320d | 2023-02-01 | 2023-12-17 |  | 0d |  |
| 2 | 1.1 | Hito 1: Inicio de obra - Acceso al Sitio | milestone | 0d | 2023-02-01 | 2023-02-01 |  | 0d |  |
| 3 | 1.2 | Hito 2: Inicio de Habilitación y Mejoramiento de accesos | milestone | 0d | 2023-02-15 | 2023-02-15 | 2FS+15d | 0d |  |
| 4 | 1.3 | Hito 3: Inicio de Movimiento de Tierras - Dique Paquete 2 | milestone | 0d | 2023-03-02 | 2023-03-02 | 3FS+15d | 52d | 0d |
| 5 | 1.4 | Hito 4: Culminación de Diques Paquete 2 | milestone | 0d | 2023-05-31 | 2023-05-31 | 4FS+90d, 25, 26, 29, 30, 43, 44, 45, 46, 47, 48 | 200d |  |
| 6 | 1.5 | Hito 5: Inicio de Movimiento de Tierras - Dique Paquete 3 | milestone | 0d | 2023-03-17 | 2023-03-17 | 3FS+30d | 0d |  |
| 7 | 1.6 | Hito 6: Culminación de Diques Paquete 3 | milestone | 0d | 2023-12-17 | 2023-12-17 | 6FS+275d, 55, 56, 59, 60, 73, 74, 75, 76, 77, 78, 85, 86, 103, 104, 105, 106, 107, 108, 111, 114, 115, 117, 123, 124, 126, 127, 133, 134, 137, 138, 151, 152, 153, 154, 155, 156, 163, 164, 168, 171, 181, 182, 183, 184, 185, 186, 193, 194, 197, 198, 211, 212, 213, 214, 215, 222, 223, 226, 227, 240, 241, 242, 243, 244, 245, 252, 253, 270, 271, 272, 273, 274, 275, 283, 284, 290, 291, 281, 125, 280 | 0d |  |
| 8 | 2 | **OBRAS PROVISIONALES** |  | 320d | 2023-02-01 | 2023-12-17 |  | 0d |  |
| 9 | 2.1 | Campamento Provisional de Obra |  | 30d | 2023-02-01 | 2023-03-02 | 2 | 290d |  |
| 10 | 2.2 | Movilización y Desmovilización de maquinaria pesada |  | 320d | 2023-02-01 | 2023-12-17 | 2 | 0d |  |
| 11 | 2.3 | Mejoramiento y Habilitación de caminos de acceso |  | 30d | 2023-02-26 | 2023-03-27 | 12 | 0d |  |
| 12 | 2.4 | Limpieza manual de material vegetal y de residuos |  | 10d | 2023-02-16 | 2023-02-25 | 3 | 0d |  |
| 13 | 2.5 | Mantenimiento de caminos de acceso |  | 240d | 2023-04-22 | 2023-12-17 | 15 | 0d |  |
| 14 | 2.6 | Tubería HDPE Corrugada Ø=630mm, para caminos de acceso (o similar) |  | 10d | 2023-03-28 | 2023-04-06 | 11 | 0d |  |
| 15 | 2.7 | Tubería HDPE Corrugada Ø=1000mm, para caminos de acceso (o similar) |  | 15d | 2023-04-07 | 2023-04-21 | 14 | 0d |  |
| 16 | 3 | **TOPOGRAFIA** |  | 320d | 2023-02-01 | 2023-12-17 |  | 0d |  |
| 17 | 3.1 | Trazo y replanteo durante la obra |  | 320d | 2023-02-01 | 2023-12-17 | 2 | 0d |  |
| 18 | 4 | **CONSTRUCCION DE DIQUES** |  | 290d | 2023-03-03 | 2023-12-17 |  | 0d |  |
| 19 | 4.1 | **DIQUE DE-PR-07-I** |  | 90d | 2023-03-03 | 2023-05-31 |  | 52d |  |
| 20 | 4.1.1 | **Excavaciones** |  | 43d | 2023-03-03 | 2023-04-14 |  | 52d |  |
| 21 | 4.1.1.1 | Desbroce |  | 4d | 2023-03-03 | 2023-03-06 | 4 | 52d | 0d |
| 22 | 4.1.1.2 | Excavación de cimentación |  | 38d | 2023-03-07 | 2023-04-13 | 21 | 52d | 0d |
| 23 | 4.1.1.3 | Perfilado y conformación de Plataforma de fundación |  | 37d | 2023-03-09 | 2023-04-14 | 22FS-36d, 24FS-36d | 52d | 0d |
| 24 | 4.1.1.4 | Excavación de uña |  | 38d | 2023-03-07 | 2023-04-13 | 21 | 52d | 0d |
| 25 | 4.1.1.5 | Conformación de material excedente en DME |  | 38d | 2023-03-07 | 2023-04-13 | 41FS-38d, 42FS-38d | 248d | 48d |
| 26 | 4.1.1.6 | Conformación de material excedente en DMO |  | 6d | 2023-03-03 | 2023-03-08 | 39FS-4d, 40FS-4d | 284d | 84d |

| ID | WBS | Task | Duration | Start | Finish | Predecessors | Total slack | Free slack |
| --- | --- | --- | --- | --- | --- | --- | --- | --- |
| 27 | 4.1.2 | **Rellenos** | 82d | 2023-03-11 | 2023-05-31 |  | 52d |  |
| 28 | 4.1.2.1 | Relleno con material granular (incluye extracción de material, zarandeo y combinación de material | 51d | 2023-03-11 | 2023-04-30 | 23FS-35d | 52d | 0d |
| 29 | 4.1.2.2 | Relleno sin compactar | 24d | 2023-05-08 | 2023-05-31 | 36FS-20d, 37FS-20d | 200d | 0d |
| 30 | 4.1.2.3 | Relleno afirmado | 7d | 2023-05-25 | 2023-05-31 | 36FS-3d, 37FS-3d | 200d | 0d |
| 31 | 4.1.2.4 | Perfilado de Talud del dique | 51d | 2023-03-12 | 2023-05-01 | 28FS-50d | 52d | 0d |
| 32 | 4.1.3 | **Geotextil** | 64d | 2023-03-23 | 2023-05-25 |  | 52d |  |
| 33 | 4.1.3.1 | Instalación de Geotextil 400 gr/m2 | 63d | 2023-03-24 | 2023-05-25 | 34FS-62d | 52d | 0d |
| 34 | 4.1.3.2 | Zanja de anclaje | 63d | 2023-03-23 | 2023-05-24 | 31FS-40d | 52d | 0d |
| 35 | 4.1.4 | **Colocación de roca** | 64d | 2023-03-25 | 2023-05-27 |  | 52d |  |
| 36 | 4.1.4.1 | Colocación de roca en uña | 64d | 2023-03-25 | 2023-05-27 | 33FS-62d | 52d | 0d |
| 37 | 4.1.4.2 | Colocación de roca en Talud | 64d | 2023-03-25 | 2023-05-27 | 33FS-62d | 52d | 0d |
| 38 | 4.1.5 | **Transportes** | 90d | 2023-03-03 | 2023-05-31 |  | 200d |  |
| 39 | 4.1.5.1 | Transporte de material orgánico (a DMO) D<=1km | 4d | 2023-03-03 | 2023-03-06 | 21SS | 284d | 0d |
| 40 | 4.1.5.2 | Transporte de material orgánico (a DMO) D>1km | 4d | 2023-03-03 | 2023-03-06 | 21SS | 284d | 0d |
| 41 | 4.1.5.3 | Transporte de material excedente (dique provisional) D<=1km | 38d | 2023-03-07 | 2023-04-13 | 22SS, 24SS | 248d | 0d |
| 42 | 4.1.5.4 | Transporte de material excedente (dique provisional) D> 1km | 38d | 2023-03-07 | 2023-04-13 | 22SS, 24SS | 248d | 0d |
| 43 | 4.1.5.5 | Transporte de material de préstamo (afirmado) D<=1km | 7d | 2023-05-25 | 2023-05-31 | 30SS | 200d | 0d |
| 44 | 4.1.5.6 | Transporte de material de préstamo (afirmado) D>1km | 7d | 2023-05-25 | 2023-05-31 | 30SS | 200d | 0d |
| 45 | 4.1.5.7 | Transporte de roca D<=1km | 64d | 2023-03-25 | 2023-05-27 | 36SS, 37SS | 204d | 4d |
| 46 | 4.1.5.8 | Transporte de roca D>1km | 64d | 2023-03-25 | 2023-05-27 | 36SS, 37SS | 204d | 4d |
| 47 | 4.1.5.9 | Transporte de material de préstamo cantera de rio (cuerpo de terraplén) D<=1km | 51d | 2023-03-11 | 2023-04-30 | 28SS | 231d | 31d |
| 48 | 4.1.5.10 | Transporte de material de préstamo cantera de rio (cuerpo de terraplén) D>1km | 51d | 2023-03-11 | 2023-04-30 | 28SS | 231d | 31d |
| 49 | 4.2 | **DIQUE DI-PR-19BIS-D** | 275d | 2023-03-18 | 2023-12-17 |  | 0d |  |
| 50 | 4.2.1 | **Excavaciones** | 34d | 2023-03-18 | 2023-04-20 |  | 0d |  |
| 51 | 4.2.1.1 | Desbroce | 5d | 2023-03-18 | 2023-03-22 | 6 | 0d |  |
| 52 | 4.2.1.2 | Excavación de cimentación | 28d | 2023-03-23 | 2023-04-19 | 51 | 0d |  |
| 53 | 4.2.1.3 | Perfilado y conformación de Plataforma de fundación | 27d | 2023-03-25 | 2023-04-20 | 52FS-26d, 54FS-26d | 0d |  |
| 54 | 4.2.1.4 | Excavación de uña | 28d | 2023-03-23 | 2023-04-19 | 51 | 0d |  |
| 55 | 4.2.1.5 | Conformación de material excedente en DME | 28d | 2023-03-23 | 2023-04-19 | 71FS-28d, 72FS-28d | 242d |  |
| 56 | 4.2.1.6 | Conformación de material excedente en DMO | 5d | 2023-03-18 | 2023-03-22 | 69FS-5d, 70FS-5d | 270d |  |

| ID | WBS | Task | Duration | Start | Finish | Predecessors | Total slack | Free slack |
| --- | --- | --- | --- | --- | --- | --- | --- | --- |
| 57 | 4.2.2 | **Rellenos** | 261d | 2023-04-01 | 2023-12-17 |  | 0d |  |
| 58 | 4.2.2.1 | Relleno con material granular (incluye extracción de material, zarandeo y combinac | 105d | 2023-04-01 | 2023-07-14 | 53FS-20d | 0d |  |
| 59 | 4.2.2.2 | Relleno sin compactar | 28d | 2023-11-20 | 2023-12-17 | 66FS-20d, 67FS-20d, 256 | 0d |  |
| 60 | 4.2.2.3 | Relleno afirmado | 24d | 2023-11-24 | 2023-12-17 | 66FS-16d, 67FS-16d, 257 | 0d |  |
| 61 | 4.2.2.4 | Perfilado de Talud del dique | 105d | 2023-04-02 | 2023-07-15 | 58FS-104d | 0d |  |
| 62 | 4.2.3 | **Geotextil** | 244d | 2023-04-09 | 2023-12-08 |  | 0d |  |
| 63 | 4.2.3.1 | Instalación de Geotextil 400 gr/m2 | 243d | 2023-04-10 | 2023-12-08 | 64FS-242d | 0d |  |
| 64 | 4.2.3.2 | Zanja de anclaje | 243d | 2023-04-09 | 2023-12-07 | 61FS-98d | 0d |  |
| 65 | 4.2.4 | **Colocación de roca** | 243d | 2023-04-11 | 2023-12-09 |  | 0d |  |
| 66 | 4.2.4.1 | Colocación de roca en uña | 243d | 2023-04-11 | 2023-12-09 | 63FS-242d | 0d |  |
| 67 | 4.2.4.2 | Colocación de roca en Talud | 243d | 2023-04-11 | 2023-12-09 | 63FS-242d | 0d |  |
| 68 | 4.2.5 | **Transportes** | 275d | 2023-03-18 | 2023-12-17 |  | 0d |  |
| 69 | 4.2.5.1 | Transporte de material orgánico (a DMO) D<=1km | 5d | 2023-03-18 | 2023-03-22 | 51SS | 270d | 0d |
| 70 | 4.2.5.2 | Transporte de material orgánico (a DMO) D>1km | 5d | 2023-03-18 | 2023-03-22 | 51SS | 270d | 0d |
| 71 | 4.2.5.3 | Transporte de material excedente (dique provisional) D<=1km | 28d | 2023-03-23 | 2023-04-19 | 52SS, 54SS | 242d | 0d |
| 72 | 4.2.5.4 | Transporte de material excedente (dique provisional) D> 1km | 28d | 2023-03-23 | 2023-04-19 | 52SS, 54SS | 242d | 0d |
| 73 | 4.2.5.5 | Transporte de material de préstamo (afirmado) D<=1km | 24d | 2023-11-24 | 2023-12-17 | 60SS | 0d |  |
| 74 | 4.2.5.6 | Transporte de material de préstamo (afirmado) D>1km | 24d | 2023-11-24 | 2023-12-17 | 60SS | 0d |  |
| 75 | 4.2.5.7 | Transporte de roca D<=1km | 243d | 2023-04-11 | 2023-12-09 | 66SS, 67SS | 8d |  |
| 76 | 4.2.5.8 | Transporte de roca D>1km | 243d | 2023-04-11 | 2023-12-09 | 66SS, 67SS | 8d |  |
| 77 | 4.2.5.9 | Transporte de material de préstamo cantera de rio (cuerpo de terraplén) D<=1km | 105d | 2023-04-01 | 2023-07-14 | 58SS | 156d |  |
| 78 | 4.2.5.10 | Transporte de material de préstamo cantera de rio (cuerpo de terraplén) D>1km | 105d | 2023-04-01 | 2023-07-14 | 58SS | 156d |  |
| 79 | 4.3 | **DIQUE DE-PR-45-D** | 54d | 2023-03-18 | 2023-05-10 |  | 114d |  |
| 80 | 4.3.1 | **Excavaciones** | 9d | 2023-03-18 | 2023-03-26 |  | 114d |  |
| 81 | 4.3.1.1 | Desbroce | 3d | 2023-03-18 | 2023-03-20 | 6 | 114d | 0d |
| 82 | 4.3.1.2 | Excavación de cimentación | 5d | 2023-03-21 | 2023-03-25 | 81 | 114d | 0d |
| 83 | 4.3.1.3 | Perfilado y conformación de Plataforma de fundación | 4d | 2023-03-23 | 2023-03-26 | 82FS-3d, 84FS-3d | 114d | 0d |
| 84 | 4.3.1.4 | Excavación de uña | 5d | 2023-03-21 | 2023-03-25 | 81 | 114d | 0d |
| 85 | 4.3.1.5 | Conformación de material excedente en DME | 3d | 2023-03-19 | 2023-03-21 | 99FS-2d, 100FS-2d | 271d |  |
| 86 | 4.3.1.6 | Conformación de material excedente en DMO | 5d | 2023-03-21 | 2023-03-25 | 101FS-5d, 102FS-5d | 267d |  |

| ID | WBS | Task | Duration | Start | Finish | Predecessors | Total slack | Free slack |
| --- | --- | --- | --- | --- | --- | --- | --- | --- |
| 87 | 4.3.2 | **Rellenos** | 46d | 2023-03-26 | 2023-05-10 |  | 114d |  |
| 88 | 4.3.2.1 | Relleno con material granular (incluye extracción de material, zarandeo y combinac | 12d | 2023-03-26 | 2023-04-06 | 83FS-1d | 114d | 0d |
| 89 | 4.3.2.2 | Relleno sin compactar | 15d | 2023-04-26 | 2023-05-10 | 96FS-3d, 97FS-3d | 206d | 2d |
| 90 | 4.3.2.3 | Relleno afirmado | 15d | 2023-04-26 | 2023-05-10 | 96FS-3d, 97FS-3d | 206d | 0d |
| 91 | 4.3.2.4 | Perfilado de Talud del dique | 12d | 2023-03-27 | 2023-04-07 | 88FS-11d | 116d | 0d |
| 92 | 4.3.3 | **Geotextil** | 31d | 2023-03-28 | 2023-04-27 |  | 116d |  |
| 93 | 4.3.3.1 | Instalación de Geotextil 400 gr/m2 | 30d | 2023-03-29 | 2023-04-27 | 94FS-29d | 116d | 0d |
| 94 | 4.3.3.2 | Zanja de anclaje | 30d | 2023-03-28 | 2023-04-26 | 91FS-11d | 116d | 0d |
| 95 | 4.3.4 | **Colocación de roca** | 30d | 2023-03-30 | 2023-04-28 |  | 116d |  |
| 96 | 4.3.4.1 | Colocación de roca en uña | 30d | 2023-03-30 | 2023-04-28 | 93FS-29d | 116d | 0d |
| 97 | 4.3.4.2 | Colocación de roca en Talud | 30d | 2023-03-30 | 2023-04-28 | 93FS-29d | 116d | 0d |
| 98 | 4.3.5 | **Transportes** | 54d | 2023-03-18 | 2023-05-10 |  | 221d |  |
| 99 | 4.3.5.1 | Transporte de material orgánico (a DMO) D<=1km | 3d | 2023-03-18 | 2023-03-20 | 81SS | 271d | 0d |
| 100 | 4.3.5.2 | Transporte de material orgánico (a DMO) D>1km | 3d | 2023-03-18 | 2023-03-20 | 81SS | 271d | 0d |
| 101 | 4.3.5.3 | Transporte de material excedente (dique provisional) D<=1km | 5d | 2023-03-21 | 2023-03-25 | 82SS, 84SS | 267d | 0d |
| 102 | 4.3.5.4 | Transporte de material excedente (dique provisional) D> 1km | 5d | 2023-03-21 | 2023-03-25 | 82SS, 84SS | 267d | 0d |
| 103 | 4.3.5.5 | Transporte de material de préstamo (afirmado) D<=1km | 15d | 2023-04-26 | 2023-05-10 | 90SS | 221d |  |
| 104 | 4.3.5.6 | Transporte de material de préstamo (afirmado) D>1km | 15d | 2023-04-26 | 2023-05-10 | 90SS | 221d |  |
| 105 | 4.3.5.7 | Transporte de roca D<=1km | 30d | 2023-03-30 | 2023-04-28 | 96SS, 97SS | 233d |  |
| 106 | 4.3.5.8 | Transporte de roca D>1km | 30d | 2023-03-30 | 2023-04-28 | 96SS, 97SS | 233d |  |
| 107 | 4.3.5.9 | Transporte de material de préstamo cantera de rio (cuerpo de terraplén) D<=1km | 12d | 2023-03-26 | 2023-04-06 | 88SS | 255d |  |
| 108 | 4.3.5.10 | Transporte de material de préstamo cantera de rio (cuerpo de terraplén) D>1km | 12d | 2023-03-26 | 2023-04-06 | 88SS | 255d |  |
| 109 | 4.4 | **DIQUE DI-PR-41A-D** | 26d | 2023-04-02 | 2023-04-27 |  | 234d |  |
| 110 | 4.4.1 | **Excavaciones** | 19d | 2023-04-02 | 2023-04-20 |  | 241d |  |
| 111 | 4.4.1.1 | Desbroce | 5d | 2023-04-02 | 2023-04-06 | 189 | 255d | 0d |
| 112 | 4.4.1.2 | Excavación de cimentación | 5d | 2023-04-14 | 2023-04-18 | 190 | 234d | 0d |
| 113 | 4.4.1.3 | Perfilado y conformación de Plataforma de fundación | 5d | 2023-04-16 | 2023-04-20 | 191, 112FS-3d | 234d | 0d |
| 114 | 4.4.1.4 | Conformación de material excedente en DME | 5d | 2023-04-14 | 2023-04-18 | 121FS-5d, 122FS-5d | 243d |  |
| 115 | 4.4.1.5 | Conformación de material excedente en DMO | 5d | 2023-04-02 | 2023-04-06 | 119FS-5d, 120FS-5d | 255d |  |

| ID | WBS | Task | Duration | Start | Finish | Predecessors | Total slack | Free slack |
| --- | --- | --- | --- | --- | --- | --- | --- | --- |
| 116 | 4.4.2 | **Rellenos** | 7d | 2023-04-21 | 2023-04-27 |  | 234d |  |
| 117 | 4.4.2.1 | Relleno con material granular (incluye extracción de material, zarandeo y combinac | 7d | 2023-04-21 | 2023-04-27 | 113 | 234d | 0d |
| 118 | 4.4.3 | **Transportes** | 26d | 2023-04-02 | 2023-04-27 |  | 234d |  |
| 119 | 4.4.3.1 | Transporte de material orgánico (a DMO) D<=1km | 5d | 2023-04-02 | 2023-04-06 | 111SS | 255d | 0d |
| 120 | 4.4.3.2 | Transporte de material orgánico (a DMO) D>1km | 5d | 2023-04-02 | 2023-04-06 | 111SS | 255d | 0d |
| 121 | 4.4.3.3 | Transporte de material excedente (dique provisional) D<=1km | 5d | 2023-04-14 | 2023-04-18 | 112SS | 243d | 0d |
| 122 | 4.4.3.4 | Transporte de material excedente (dique provisional) D> 1km | 5d | 2023-04-14 | 2023-04-18 | 112SS | 243d | 0d |
| 123 | 4.4.3.5 | Transporte de material de préstamo (afirmado) D<=1km | 7d | 2023-04-21 | 2023-04-27 | 117SS | 234d |  |
| 124 | 4.4.3.6 | Transporte de material de préstamo (afirmado) D>1km | 7d | 2023-04-21 | 2023-04-27 | 117SS | 234d |  |
| 125 | 4.4.3.7 | Transporte de material de préstamo cantera de rio (cuerpo de terraplén) D<=1km | 7d | 2023-04-21 | 2023-04-27 | 117SS | 234d |  |
| 126 | 4.4.3.8 | Transporte de material de préstamo cantera de rio (cuerpo de terraplén) D>1km | 7d | 2023-04-21 | 2023-04-27 | 117SS | 234d |  |
| 127 | 4.5 | **DIQUE DI-PR-41-D** | 68d | 2023-03-21 | 2023-05-27 |  | 121d |  |
| 128 | 4.5.1 | **Excavaciones** | 13d | 2023-03-21 | 2023-04-02 |  | 121d |  |
| 129 | 4.5.1.1 | Desbroce | 5d | 2023-03-21 | 2023-03-25 | 81 | 121d | 0d |
| 130 | 4.5.1.2 | Excavación de cimentación | 7d | 2023-03-26 | 2023-04-01 | 82, 129 | 121d | 0d |
| 131 | 4.5.1.3 | Perfilado y conformación de Plataforma de fundación | 6d | 2023-03-28 | 2023-04-02 | 83, 130FS-5d, 132FS-5d | 121d | 1d |
| 132 | 4.5.1.4 | Excavación de uña | 7d | 2023-03-26 | 2023-04-01 | 84, 129 | 121d | 0d |
| 133 | 4.5.1.5 | Conformación de material excedente en DME | 7d | 2023-03-26 | 2023-04-01 | 149FS-7d, 150FS-7d | 260d |  |
| 134 | 4.5.1.6 | Conformación de material excedente en DMO | 5d | 2023-03-21 | 2023-03-25 | 147FS-5d, 148FS-5d | 267d |  |
| 135 | 4.5.2 | **Rellenos** | 51d | 2023-04-07 | 2023-05-27 |  | 114d |  |
| 136 | 4.5.2.1 | Relleno con material granular (incluye extracción de material, zarandeo y combinac | 19d | 2023-04-07 | 2023-04-25 | 88, 131FS-3d | 114d | 0d |
| 137 | 4.5.2.2 | Relleno sin compactar | 15d | 2023-05-13 | 2023-05-27 | 89, 144FS-13d, 145FS-13d | 204d |  |
| 138 | 4.5.2.3 | Relleno afirmado | 15d | 2023-05-13 | 2023-05-27 | 90, 144FS-13d, 145FS-13d | 204d | 0d |
| 139 | 4.5.2.4 | Perfilado de Talud del dique | 19d | 2023-04-10 | 2023-04-28 | 91, 136FS-16d | 114d | 0d |

| ID | WBS | Task | Duration | Start | Finish | Predecessors | Total slack | Free slack |
| --- | --- | --- | --- | --- | --- | --- | --- | --- |
| 140 | 4.5.3 | **Geotextil** | 26d | 2023-04-29 | 2023-05-24 |  | 114d |  |
| 141 | 4.5.3.1 | Instalación de Geotextil 400 gr/m2 | 25d | 2023-04-30 | 2023-05-24 | 93, 142FS-24d | 114d | 0d |
| 142 | 4.5.3.2 | Zanja de anclaje | 25d | 2023-04-29 | 2023-05-23 | 94, 139 | 114d | 0d |
| 143 | 4.5.4 | **Colocación de roca** | 25d | 2023-05-01 | 2023-05-25 |  | 114d | 0d |
| 144 | 4.5.4.1 | Colocación de roca en uña | 25d | 2023-05-01 | 2023-05-25 | 96, 141FS-24d | 114d | 0d |
| 145 | 4.5.4.2 | Colocación de roca en Talud | 25d | 2023-05-01 | 2023-05-25 | 97, 141FS-24d | 114d | 0d |
| 146 | 4.5.5 | **Transportes** | 68d | 2023-03-21 | 2023-05-27 |  | 204d |  |
| 147 | 4.5.5.1 | Transporte de material orgánico (a DMO) D<=1km | 5d | 2023-03-21 | 2023-03-25 | 129SS | 267d | 0d |
| 148 | 4.5.5.2 | Transporte de material orgánico (a DMO) D>1km | 5d | 2023-03-21 | 2023-03-25 | 129SS | 267d | 0d |
| 149 | 4.5.5.3 | Transporte de material excedente (dique provisional) D<=1km | 7d | 2023-03-26 | 2023-04-01 | 130SS, 132SS | 260d | 0d |
| 150 | 4.5.5.4 | Transporte de material excedente (dique provisional) D> 1km | 7d | 2023-03-26 | 2023-04-01 | 130SS, 132SS | 260d | 0d |
| 151 | 4.5.5.5 | Transporte de material de préstamo (afirmado) D<=1km | 15d | 2023-05-13 | 2023-05-27 | 138SS | 204d |  |
| 152 | 4.5.5.6 | Transporte de material de préstamo (afirmado) D>1km | 15d | 2023-05-13 | 2023-05-27 | 138SS | 204d |  |
| 153 | 4.5.5.7 | Transporte de roca D<=1km | 25d | 2023-05-01 | 2023-05-25 | 144SS, 145SS | 206d |  |
| 154 | 4.5.5.8 | Transporte de roca D>1km | 25d | 2023-05-01 | 2023-05-25 | 144SS, 145SS | 206d |  |
| 155 | 4.5.5.9 | Transporte de material de préstamo cantera de rio (cuerpo de terraplén) D<=1km | 19d | 2023-04-07 | 2023-04-25 | 136SS | 236d |  |
| 156 | 4.5.5.10 | Transporte de material de préstamo cantera de rio (cuerpo de terraplén) D>1km | 19d | 2023-04-07 | 2023-04-25 | 136SS | 236d |  |
| 157 | 4.6 | **DIQUE DE-PR-19-D** | 188d | 2023-04-22 | 2023-10-26 |  | 43d |  |
| 158 | 4.6.1 | **Excavaciones** | 56d | 2023-04-22 | 2023-06-16 |  | 43d |  |
| 159 | 4.6.1.1 | Desbroce | 10d | 2023-04-22 | 2023-05-01 | 218 | 43d | 0d |
| 160 | 4.6.1.2 | Excavación de cimentación | 12d | 2023-05-04 | 2023-05-15 | 219, 159 | 54d | 0d |
| 161 | 4.6.1.3 | Perfilado y conformación de Plataforma de fundación | 20d | 2023-05-28 | 2023-06-16 | 162 | 54d | 0d |
| 162 | 4.6.1.4 | Excavación de uña | 12d | 2023-05-16 | 2023-05-27 | 160 | 54d | 0d |
| 163 | 4.6.1.5 | Conformación de material excedente en DME | 24d | 2023-05-04 | 2023-05-27 | 179FS-24d, 180FS-24d | 204d |  |
| 164 | 4.6.1.6 | Conformación de material excedente en DMO | 10d | 2023-04-22 | 2023-05-01 | 177FS-10d, 178FS-10d | 230d |  |

| ID | WBS | Task | Duration | Start | Finish | Predecessors | Total slack | Free slack |
| --- | --- | --- | --- | --- | --- | --- | --- | --- |
| 165 | 4.6.2 | **Rellenos** | 132d | 2023-06-17 | 2023-10-26 |  | 52d |  |
| 166 | 4.6.2.1 | Relleno con material granular (incluye extracción de material, zarandeo y combinac | 45d | 2023-06-17 | 2023-07-31 | 225, 161 | 54d | 0d |
| 167 | 4.6.2.2 | Relleno sin compactar | 12d | 2023-10-10 | 2023-10-21 | 174FS-5d, 175FS-5d | 52d | 0d |
| 168 | 4.6.2.3 | Relleno afirmado | 5d | 2023-10-22 | 2023-10-26 | 167 | 52d | 0d |
| 169 | 4.6.2.4 | Perfilado de Talud del dique | 46d | 2023-06-18 | 2023-08-02 | 228, 166FS-44d | 54d | 0d |
| 170 | 4.6.3 | **Geotextil** | 71d | 2023-08-03 | 2023-10-12 |  | 54d |  |
| 171 | 4.6.3.1 | Instalación de Geotextil 400 gr/m2 | 70d | 2023-08-04 | 2023-10-12 | 230, 172FS-69d | 66d |  |
| 172 | 4.6.3.2 | Zanja de anclaje | 70d | 2023-08-03 | 2023-10-11 | 231, 169 | 54d | 0d |
| 173 | 4.6.4 | **Colocación de roca** | 70d | 2023-08-06 | 2023-10-14 |  | 52d |  |
| 174 | 4.6.4.1 | Colocación de roca en uña | 70d | 2023-08-06 | 2023-10-14 | 233, 172FS-69d | 52d | 0d |
| 175 | 4.6.4.2 | Colocación de roca en Talud | 70d | 2023-08-06 | 2023-10-14 | 234, 172FS-69d | 52d | 0d |
| 176 | 4.6.5 | **Transportes** | 188d | 2023-04-22 | 2023-10-26 |  | 52d |  |
| 177 | 4.6.5.1 | Transporte de material orgánico (a DMO) D<=1km | 10d | 2023-04-22 | 2023-05-01 | 159SS | 230d | 0d |
| 178 | 4.6.5.2 | Transporte de material orgánico (a DMO) D>1km | 10d | 2023-04-22 | 2023-05-01 | 159SS | 230d | 0d |
| 179 | 4.6.5.3 | Transporte de material excedente (dique provisional) D<=1km | 24d | 2023-05-04 | 2023-05-27 | 160SS | 204d | 0d |
| 180 | 4.6.5.4 | Transporte de material excedente (dique provisional) D> 1km | 24d | 2023-05-04 | 2023-05-27 | 160SS | 204d | 0d |
| 181 | 4.6.5.5 | Transporte de material de préstamo (afirmado) D<=1km | 5d | 2023-10-22 | 2023-10-26 | 168SS | 52d |  |
| 182 | 4.6.5.6 | Transporte de material de préstamo (afirmado) D>1km | 5d | 2023-10-22 | 2023-10-26 | 168SS | 52d |  |
| 183 | 4.6.5.7 | Transporte de roca D<=1km | 70d | 2023-08-06 | 2023-10-14 | 174SS, 175SS | 64d |  |
| 184 | 4.6.5.8 | Transporte de roca D>1km | 70d | 2023-08-06 | 2023-10-14 | 174SS, 175SS | 64d |  |
| 185 | 4.6.5.9 | Transporte de material de préstamo cantera de rio (cuerpo de terraplén) D<=1km | 45d | 2023-06-17 | 2023-07-31 | 166SS | 139d |  |
| 186 | 4.6.5.10 | Transporte de material de préstamo cantera de rio (cuerpo de terraplén) D>1km | 45d | 2023-06-17 | 2023-07-31 | 166SS | 139d |  |
| 187 | 4.7 | **DIQUE DI-PR-44-D** | 153d | 2023-03-26 | 2023-08-25 |  | 114d |  |
| 188 | 4.7.1 | **Excavaciones** | 20d | 2023-03-26 | 2023-04-14 |  | 127d |  |
| 189 | 4.7.1.1 | Desbroce | 7d | 2023-03-26 | 2023-04-01 | 129 | 127d | 0d |
| 190 | 4.7.1.2 | Excavación de cimentación | 12d | 2023-04-02 | 2023-04-13 | 130, 189 | 127d | 0d |
| 191 | 4.7.1.3 | Perfilado y conformación de Plataforma de fundación | 11d | 2023-04-04 | 2023-04-14 | 131, 190FS-10d, 192FS-10d | 127d | 1d |
| 192 | 4.7.1.4 | Excavación de uña | 12d | 2023-04-02 | 2023-04-13 | 132, 189 | 127d | 0d |
| 193 | 4.7.1.5 | Conformación de material excedente en DME | 12d | 2023-04-02 | 2023-04-13 | 209FS-12d, 210FS-12d | 248d |  |
| 194 | 4.7.1.6 | Conformación de material excedente en DMO | 7d | 2023-03-26 | 2023-04-01 | 207FS-7d, 208FS-7d | 260d |  |

| ID | WBS | Task | Duration | Start | Finish | Predecessors | Total slack | Free slack |
| --- | --- | --- | --- | --- | --- | --- | --- | --- |
| 195 | 4.7.2 | **Rellenos** | 122d | 2023-04-26 | 2023-08-25 |  | 114d |  |
| 196 | 4.7.2.1 | Relleno con material granular (incluye extracción de material, zarandeo y combinac | 33d | 2023-04-26 | 2023-05-28 | 136, 191 | 116d | 0d |
| 197 | 4.7.2.2 | Relleno sin compactar | 15d | 2023-08-11 | 2023-08-25 | 204FS-11d, 205FS-11d | 114d |  |
| 198 | 4.7.2.3 | Relleno afirmado | 7d | 2023-08-19 | 2023-08-25 | 204FS-3d, 205FS-3d | 114d | 0d |
| 199 | 4.7.2.4 | Perfilado de Talud del dique | 33d | 2023-04-29 | 2023-05-31 | 139, 196FS-32d | 114d | 0d |
| 200 | 4.7.3 | **Geotextil** | 89d | 2023-05-24 | 2023-08-20 |  | 114d |  |
| 201 | 4.7.3.1 | Instalación de Geotextil 400 gr/m2 | 88d | 2023-05-25 | 2023-08-20 | 202FS-87d, 141 | 114d | 0d |
| 202 | 4.7.3.2 | Zanja de anclaje | 88d | 2023-05-24 | 2023-08-19 | 199FS-8d, 142 | 114d | 0d |
| 203 | 4.7.4 | **Colocación de roca** | 88d | 2023-05-26 | 2023-08-21 |  | 114d |  |
| 204 | 4.7.4.1 | Colocación de roca en uña | 88d | 2023-05-26 | 2023-08-21 | 201FS-87d, 143 | 114d | 0d |
| 205 | 4.7.4.2 | Colocación de roca en Talud | 88d | 2023-05-26 | 2023-08-21 | 201FS-87d, 144 | 114d | 0d |
| 206 | 4.7.5 | **Transportes** | 153d | 2023-03-26 | 2023-08-25 |  | 114d |  |
| 207 | 4.7.5.1 | Transporte de material orgánico (a DMO) D<=1km | 7d | 2023-03-26 | 2023-04-01 | 189SS | 260d | 0d |
| 208 | 4.7.5.2 | Transporte de material orgánico (a DMO) D>1km | 7d | 2023-03-26 | 2023-04-01 | 189SS | 260d | 0d |
| 209 | 4.7.5.3 | Transporte de material excedente (dique provisional) D<=1km | 12d | 2023-04-02 | 2023-04-13 | 190SS, 192SS | 248d | 0d |
| 210 | 4.7.5.4 | Transporte de material excedente (dique provisional) D> 1km | 12d | 2023-04-02 | 2023-04-13 | 190SS, 192SS | 248d | 0d |
| 211 | 4.7.5.5 | Transporte de material de préstamo (afirmado) D<=1km | 7d | 2023-08-19 | 2023-08-25 | 198SS | 114d |  |
| 212 | 4.7.5.6 | Transporte de material de préstamo (afirmado) D>1km | 7d | 2023-08-19 | 2023-08-25 | 198SS | 114d |  |
| 213 | 4.7.5.7 | Transporte de roca D<=1km | 88d | 2023-05-26 | 2023-08-21 | 204SS, 205SS | 118d |  |
| 214 | 4.7.5.8 | Transporte de roca D>1km | 88d | 2023-05-26 | 2023-08-21 | 204SS, 205SS | 118d |  |
| 215 | 4.7.5.9 | Transporte de material de préstamo cantera de rio (cuerpo de terraplén) D<=1km | 33d | 2023-04-26 | 2023-05-28 | 196SS | 203d |  |
| 216 | 4.8 | **DIQUE DI-PR-18-I** | 113d | 2023-04-17 | 2023-08-07 |  | 43d |  |
| 217 | 4.8.1 | **Excavaciones** | 18d | 2023-04-17 | 2023-05-04 |  | 43d |  |
| 218 | 4.8.1.1 | Desbroce | 5d | 2023-04-17 | 2023-04-21 | 6FS+30d | 43d | 0d |
| 219 | 4.8.1.2 | Excavación de cimentación | 12d | 2023-04-22 | 2023-05-03 | 218 | 53d | 0d |
| 220 | 4.8.1.3 | Perfilado y conformación de Plataforma de fundación | 11d | 2023-04-24 | 2023-05-04 | 219FS-10d, 221FS-10d | 53d | 0d |
| 221 | 4.8.1.4 | Excavación de uña | 12d | 2023-04-22 | 2023-05-03 | 218 | 53d | 0d |
| 222 | 4.8.1.5 | Conformación de material excedente en DME | 12d | 2023-04-22 | 2023-05-03 | 238FS-12d, 239FS-12d | 228d |  |
| 223 | 4.8.1.6 | Conformación de material excedente en DMO | 5d | 2023-04-17 | 2023-04-21 | 236FS-5d, 237FS-5d | 240d |  |

| ID | WBS | Task | Duration | Start | Finish | Predecessors | Total slack | Free slack |
| --- | --- | --- | --- | --- | --- | --- | --- | --- |
| 224 | 4.8.2 | **Rellenos** | 99d | 2023-05-01 | 2023-08-07 |  | 53d |  |
| 225 | 4.8.2.1 | Relleno con material granular (incluye extracción de material, zarandeo y combinac | 47d | 2023-05-01 | 2023-06-16 | 28, 220FS-4d | 53d | 0d |
| 226 | 4.8.2.2 | Relleno sin compactar | 15d | 2023-07-24 | 2023-08-07 | 233FS-13d, 234FS-13d | 132d |  |
| 227 | 4.8.2.3 | Relleno afirmado | 15d | 2023-07-24 | 2023-08-07 | 233FS-13d, 234FS-13d | 132d | 0d |
| 228 | 4.8.2.4 | Perfilado de Talud del dique | 47d | 2023-05-02 | 2023-06-17 | 225FS-46d | 53d | 0d |
| 229 | 4.8.3 | **Geotextil** | 71d | 2023-05-25 | 2023-08-03 |  | 53d |  |
| 230 | 4.8.3.1 | Instalación de Geotextil 400 gr/m2 | 70d | 2023-05-26 | 2023-08-03 | 33, 231FS-69d | 53d | 0d |
| 231 | 4.8.3.2 | Zanja de anclaje | 70d | 2023-05-25 | 2023-08-02 | 34, 228FS-24d | 53d | 0d |
| 232 | 4.8.4 | **Colocación de roca** | 70d | 2023-05-28 | 2023-08-05 |  | 52d |  |
| 233 | 4.8.4.1 | Colocación de roca en uña | 70d | 2023-05-28 | 2023-08-05 | 36, 230FS-69d | 52d | 0d |
| 234 | 4.8.4.2 | Colocación de roca en Talud | 70d | 2023-05-28 | 2023-08-05 | 37, 230FS-69d | 52d | 0d |
| 235 | 4.8.5 | **Transportes** | 113d | 2023-04-17 | 2023-08-07 |  | 132d |  |
| 236 | 4.8.5.1 | Transporte de material orgánico (a DMO) D<=1km | 5d | 2023-04-17 | 2023-04-21 | 218SS | 240d | 0d |
| 237 | 4.8.5.2 | Transporte de material orgánico (a DMO) D>1km | 5d | 2023-04-17 | 2023-04-21 | 218SS | 240d | 0d |
| 238 | 4.8.5.3 | Transporte de material excedente (dique provisional) D<=1km | 12d | 2023-04-22 | 2023-05-03 | 219SS, 221SS | 228d | 0d |
| 239 | 4.8.5.4 | Transporte de material excedente (dique provisional) D> 1km | 12d | 2023-04-22 | 2023-05-03 | 219SS, 221SS | 228d | 0d |
| 240 | 4.8.5.5 | Transporte de material de préstamo (afirmado) D<=1km | 15d | 2023-07-24 | 2023-08-07 | 227SS | 132d |  |
| 241 | 4.8.5.6 | Transporte de material de préstamo (afirmado) D>1km | 15d | 2023-07-24 | 2023-08-07 | 227SS | 132d |  |
| 242 | 4.8.5.7 | Transporte de roca D<=1km | 70d | 2023-05-28 | 2023-08-05 | 233SS, 234SS | 134d |  |
| 243 | 4.8.5.8 | Transporte de roca D>1km | 70d | 2023-05-28 | 2023-08-05 | 233SS, 234SS | 134d |  |
| 244 | 4.8.5.9 | Transporte de material de préstamo cantera de rio (cuerpo de terraplén) D<=1km | 47d | 2023-05-01 | 2023-06-16 | 225SS | 184d |  |
| 245 | 4.8.5.10 | Transporte de material de préstamo cantera de rio (cuerpo de terraplén) D>1km | 47d | 2023-05-01 | 2023-06-16 | 225SS | 184d |  |
| 246 | 4.9 | **DIQUE DI-PR-20-D** | 251d | 2023-03-18 | 2023-11-23 |  | 0d |  |
| 247 | 4.9.1 | **Excavaciones** | 33d | 2023-03-18 | 2023-04-19 |  | 0d |  |
| 248 | 4.9.1.1 | Desbroce | 5d | 2023-03-18 | 2023-03-22 | 6 | 0d |  |
| 249 | 4.9.1.2 | Excavación de cimentación | 27d | 2023-03-23 | 2023-04-18 | 248 | 0d |  |
| 250 | 4.9.1.3 | Perfilado y conformación de Plataforma de fundación | 26d | 2023-03-25 | 2023-04-19 | 249FS-25d, 251FS-25d | 0d |  |
| 251 | 4.9.1.4 | Excavación de uña | 27d | 2023-03-23 | 2023-04-18 | 248 | 0d |  |
| 252 | 4.9.1.5 | Conformación de material excedente en DME | 28d | 2023-03-23 | 2023-04-19 | 268FS-27d, 269FS-27d | 242d |  |
| 253 | 4.9.1.6 | Conformación de material excedente en DMO | 9d | 2023-03-18 | 2023-03-26 | 266FS-5d, 267FS-5d | 266d |  |

| ID | WBS | Task | Duration | Start | Finish | Predecessors | Total slack | Free slack |
| --- | --- | --- | --- | --- | --- | --- | --- | --- |
| 254 | 4.9.2 | **Rellenos** | 238d | 2023-03-31 | 2023-11-23 |  | 0d |  |
| 255 | 4.9.2.1 | Relleno con material granular (incluye extracción de material, zarandeo y combinac | 105d | 2023-03-31 | 2023-07-13 | 250FS-20d | 0d |  |
| 256 | 4.9.2.2 | Relleno sin compactar | 32d | 2023-10-19 | 2023-11-19 | 263FS-15d, 264FS-15d | 0d |  |
| 257 | 4.9.2.3 | Relleno afirmado | 21d | 2023-11-03 | 2023-11-23 | 263 | 0d |  |
| 258 | 4.9.2.4 | Perfilado de Talud del dique | 105d | 2023-04-01 | 2023-07-14 | 255FS-104d | 0d |  |
| 259 | 4.9.3 | **Geotextil** | 208d | 2023-04-08 | 2023-11-01 |  | 0d |  |
| 260 | 4.9.3.1 | Instalación de Geotextil 400 gr/m2 | 207d | 2023-04-09 | 2023-11-01 | 261FS-206d | 0d |  |
| 261 | 4.9.3.2 | Zanja de anclaje | 207d | 2023-04-08 | 2023-10-31 | 258FS-98d | 0d |  |
| 262 | 4.9.4 | **Colocación de roca** | 207d | 2023-04-10 | 2023-11-02 |  | 0d |  |
| 263 | 4.9.4.1 | Colocación de roca en uña | 207d | 2023-04-10 | 2023-11-02 | 260FS-206d | 0d |  |
| 264 | 4.9.4.2 | Colocación de roca en Talud | 207d | 2023-04-10 | 2023-11-02 | 260FS-206d | 0d |  |
| 265 | 4.9.5 | **Transportes** | 251d | 2023-03-18 | 2023-11-23 |  | 24d |  |
| 266 | 4.9.5.1 | Transporte de material orgánico (a DMO) D<=1km | 5d | 2023-03-18 | 2023-03-22 | 248SS | 266d | 0d |
| 267 | 4.9.5.2 | Transporte de material orgánico (a DMO) D>1km | 5d | 2023-03-18 | 2023-03-22 | 248SS | 266d | 0d |
| 268 | 4.9.5.3 | Transporte de material excedente (dique provisional) D<=1km | 27d | 2023-03-23 | 2023-04-18 | 249SS, 251SS | 242d | 0d |
| 269 | 4.9.5.4 | Transporte de material excedente (dique provisional) D> 1km | 27d | 2023-03-23 | 2023-04-18 | 249SS, 251SS | 242d | 0d |
| 270 | 4.9.5.5 | Transporte de material de préstamo (afirmado) D<=1km | 21d | 2023-11-03 | 2023-11-23 | 257SS | 24d |  |
| 271 | 4.9.5.6 | Transporte de material de préstamo (afirmado) D>1km | 21d | 2023-11-03 | 2023-11-23 | 257SS | 24d |  |
| 272 | 4.9.5.7 | Transporte de roca D<=1km | 207d | 2023-04-10 | 2023-11-02 | 263SS, 264SS | 45d |  |
| 273 | 4.9.5.8 | Transporte de roca D>1km | 207d | 2023-04-10 | 2023-11-02 | 263SS, 264SS | 45d |  |
| 274 | 4.9.5.9 | Transporte de material de préstamo cantera de rio (cuerpo de terraplén) D<=1km | 105d | 2023-03-31 | 2023-07-13 | 255SS | 157d |  |
| 275 | 4.9.5.10 | Transporte de material de préstamo cantera de rio (cuerpo de terraplén) D>1km | 105d | 2023-03-31 | 2023-07-13 | 255SS | 157d |  |
| 276 | 4.10 | **DIQUE DI-PR-39-I** | 187d | 2023-05-02 | 2023-11-04 |  | 43d |  |
| 277 | 4.10.1 | **Excavaciones** | 45d | 2023-05-02 | 2023-06-15 |  | 43d |  |
| 278 | 4.10.1.1 | Desbroce | 5d | 2023-05-02 | 2023-05-06 | 159 | 43d | 0d |
| 279 | 4.10.1.2 | Excavación bajo nivel freático | 40d | 2023-05-07 | 2023-06-15 | 278 | 43d | 0d |
| 280 | 4.10.1.3 | Conformación de material excedente en DME | 40d | 2023-05-07 | 2023-06-15 | 288FS-40d, 289FS-40d | 185d |  |
| 281 | 4.10.1.4 | Conformación de material excedente en DMO | 5d | 2023-05-02 | 2023-05-06 | 286FS-5d, 287FS-5d | 225d |  |

| ID | WBS | Task | Duration | Start | Finish | Predecessors | Total slack | Free slack |
| --- | --- | --- | --- | --- | --- | --- | --- | --- |
| 282 | 4.10.2 | **Colocación de roca** | 142d | 2023-06-16 | 2023-11-04 |  | 43d |  |
| 283 | 4.10.2.1 | Colocación de roca en uña | 142d | 2023-06-16 | 2023-11-04 | 279 | 43d | 0d |
| 284 | 4.10.2.2 | Colocación de roca en Talud | 142d | 2023-06-16 | 2023-11-04 | 279 | 43d | 0d |
| 285 | 4.10.3 | **Transportes** | 187d | 2023-05-02 | 2023-11-04 |  | 43d |  |
| 286 | 4.10.3.1 | Transporte de material orgánico (a DMO) D<=1km | 5d | 2023-05-02 | 2023-05-06 | 278SS | 225d | 0d |
| 287 | 4.10.3.2 | Transporte de material orgánico (a DMO) D>1km | 5d | 2023-05-02 | 2023-05-06 | 278SS | 225d | 0d |
| 288 | 4.10.3.3 | Transporte de material excedente (dique provisional) D<=1km | 40d | 2023-05-07 | 2023-06-15 | 279SS | 185d | 0d |
| 289 | 4.10.3.4 | Transporte de material excedente (dique provisional) D> 1km | 40d | 2023-05-07 | 2023-06-15 | 279SS | 185d | 0d |
| 290 | 4.10.3.5 | Transporte de roca D<=1km | 142d | 2023-06-16 | 2023-11-04 | 283SS, 284SS | 43d |  |
| 291 | 4.10.3.6 | Transporte de roca D>1km | 142d | 2023-06-16 | 2023-11-04 | 283SS, 284SS | 43d |  |
| 292 | 5 | **SEÑALIZACIÓN** | 320d | 2023-02-01 | 2023-12-17 |  | 0d |  |
| 293 | 5.1 | Señalización de obra | 320d | 2023-02-01 | 2023-12-17 | 2 | 0d |  |
| 294 | 6 | **CALIDAD** | 320d | 2023-02-01 | 2023-12-17 |  | 0d |  |
| 295 | 6.1 | Control de calidad | 320d | 2023-02-01 | 2023-12-17 | 2 | 0d |  |
| 296 | 7 | **OBRAS CIVILES** | 320d | 2023-02-01 | 2023-12-17 |  | 0d |  |
| 297 | 7.1 | Trazo y replanteo de interferencia | 320d | 2023-02-01 | 2023-12-17 | 2 | 0d |  |
| 298 | 7.2 | Desvío provisional con tubería | 28d | 2023-02-02 | 2023-03-01 | 300FS-11d | 0d |  |
| 299 | 7.3 | Desvío provisional en tierras | 93d | 2023-03-02 | 2023-06-02 | 298 | 0d |  |
| 300 | 7.4 | Limpieza de terreno manual | 12d | 2023-02-01 | 2023-02-12 | 2 | 0d |  |
| 301 | 7.5 | Excavaciones no clasificada para estructuras | 7d | 2023-03-17 | 2023-03-23 | 299FS-78d | 0d |  |
| 302 | 7.6 | Excavacion no clasificada de zanja | 137d | 2023-03-24 | 2023-08-07 | 301 | 0d |  |
| 303 | 7.7 | Relleno estructural | 44d | 2023-06-29 | 2023-08-11 | 302FS-40d | 0d |  |
| 304 | 7.8 | Suministro de roca (Alcantarillas) | 19d | 2023-08-12 | 2023-08-30 | 303 | 104d | 0d |
| 305 | 7.9 | Colocación de roca en uña (Alcantarillas) | 5d | 2023-08-31 | 2023-09-04 | 304 | 104d |  |
| 306 | 7.10 | Concreto de Nivelacion (f'c=100 kg/cm2) | 5d | 2023-08-12 | 2023-08-16 | 303 | 0d |  |
| 307 | 7.11 | Concreto Clase F (f'c=140 kg/cm2) | 7d | 2023-08-17 | 2023-08-23 | 306, 310FS-25d | 0d |  |
| 308 | 7.12 | Concreto Clase C (f'c=280 kg/cm2) Premezclado - Cimientos reforzados | 44d | 2023-08-24 | 2023-10-06 | 307 | 0d |  |
| 309 | 7.13 | Concreto Clase C (f'c=280 kg/cm2) Premezclado - Muros de contencion | 46d | 2023-10-07 | 2023-11-21 | 308, 311FS-44d, 312FS-44d | 0d |  |
| 310 | 7.14 | Encofrado y Desencofrado Caravista | 45d | 2023-07-28 | 2023-09-10 | 303FS-15d | 0d |  |
| 311 | 7.15 | Encofrado y Desencofrado Cara Oculta | 70d | 2023-09-11 | 2023-11-19 | 310 | 0d |  |
| 312 | 7.16 | Acero de refuerzo f'y=4200kg/cm2 | 115d | 2023-07-28 | 2023-11-19 | 303FS-15d | 0d |  |
| 313 | 7.17 | Emboquillado de piedra e=0.20m | 55d | 2023-10-03 | 2023-11-26 | 309FS-50d | 0d |  |
| 314 | 7.18 | Emboquillado de piedra e=0.30m | 10d | 2023-11-27 | 2023-12-06 | 313 | 0d |  |
| 315 | 7.19 | Emboquillado de piedra e=0.50m | 11d | 2023-12-07 | 2023-12-17 | 314 | 0d |  |
| 316 | 7.20 | Cama de arena e=0.20m | 10d | 2023-09-10 | 2023-09-19 | 303, 308FS-27d | 0d |  |
| 317 | 7.21 | Tubería HDPE Corrugada Ø=900mm (Suministro e instalación) | 3d | 2023-09-20 | 2023-09-22 | 316 | 0d |  |
| 318 | 7.22 | Tubería HDPE Corrugada Ø=1200mm (Suministro e instalación) | 2d | 2023-09-23 | 2023-09-24 | 317 | 0d |  |
| 319 | 7.23 | Compuertas Charnela Ø900 (Suministro e instalacion) | 9d | 2023-09-25 | 2023-10-03 | 318 | 0d |  |
| 320 | 7.24 | Compuertas Charnela Ø1200 (Suministro e instalacion) | 3d | 2023-10-04 | 2023-10-06 | 319 | 0d |  |
| 321 | 7.25 | Sello en juntas | 18d | 2023-10-07 | 2023-10-24 | 320 | 0d |  |
| 322 | 7.26 | Waterstop (anillos de estanqueidad) | 3d | 2023-10-25 | 2023-10-27 | 321 | 0d |  |
| 323 | 7.27 | Pintura bituminosa | 33d | 2023-10-28 | 2023-11-29 | 322 | 0d |  |
| 324 | 7.28 | Relleno con material granular (incluye extracción de material, zarandeo y combinac | 18d | 2023-11-30 | 2023-12-17 | 323 | 0d |  |

| ID | WBS | Task | Type | Duration | Start | Finish | Predecessors | Total slack |
| --- | --- | --- | --- | --- | --- | --- | --- | --- |
| 325 | 8 | **ACCESOS** |  | 28d | 2023-11-20 | 2023-12-17 |  | 0d |
| 326 | 8.1 | **Superficie de rodadura** |  | 28d | 2023-11-20 | 2023-12-17 |  | 0d |
| 327 | 8.1.1 | Concreto clase C (f'c=280 kg/cm2) en losa |  | 15d | 2023-11-30 | 2023-12-14 | 330 | 0d |
| 328 | 8.1.2 | Encofrado y desencofrado pavimento rígido e=0.15m |  | 22d | 2023-11-20 | 2023-12-11 | 311 | 6d |
| 329 | 8.1.3 | Junta en Pavimentos con Pasadores |  | 3d | 2023-12-15 | 2023-12-17 | 327 | 0d |
| 330 | 8.1.4 | Concreto Ciclopeo f'c=210 kg/cm2 + 30% PM |  | 8d | 2023-11-22 | 2023-11-29 | 309 | 0d |
| 331 | 9 | FIN | milestone | 0d | 2023-12-17 | 2023-12-17 | 9, 10, 13, 17, 5, 276, 293, 295, 305, 315, 324, 328, 329, 297 | 0d |
